# Module5_Reports

Schedule from MS Project, 2019-01-07 to 2019-06-12, costs in $, A marks actual dates.

## Calendars

- Standard: Mon-Fri 08:00-12:00, 13:00-17:00; Sat-Sun off.

## Resources

| Resource | Group | Rate | Notes |
| --- | --- | --- | --- |
| Steve Masters | PMO | 75 | Cost table A is for project management duties. Cost table B is for developer lead duties. |
| Rob Young |  | 25 |  |
| Kim Ralls |  | 22 |  |
| Paper |  |  |  |
| Flight |  |  |  |
| Project Budget |  |  |  |
| Project Manager |  |  |  |

## Schedule

| ID | WBS | Task | Type | Duration | Start | Finish | Predecessors | Complete | Baseline start | Baseline finish | Baseline duration | Total slack | Resources | Work | Actual work | Cost | Baseline cost | Actual cost |
| --- | --- | --- | --- | --- | --- | --- | --- | --- | --- | --- | --- | --- | --- | --- | --- | --- | --- | --- |
| 1 | 1 | **Scope** |  | 5d | 2019-01-07 A | 2019-01-11 A |  | 100% | 2019-01-07 | 2019-01-14 | 6d |  |  | 28h | 28h | 4,150 | 4,300 | 3,700 |
| 2 | 1.1 | Determine project scope |  | 1d | 2019-01-07 A | 2019-01-07 A |  | 100% | 2019-01-07 | 2019-01-07 | 1d |  | Steve Masters | 8h | 8h | 600 | 600 | 600 |
| 3 | 1.2 | Secure project sponsorship |  | 2d | 2019-01-08 A | 2019-01-09 A | 2 | 100% | 2019-01-08 | 2019-01-10 | 3d |  | Steve Masters [25%]; Flight [0.6%] | 4h | 4h | 750 | 900 | 300 |
| 4 | 1.3 | Define preliminary resources |  | 1d | 2019-01-10 A | 2019-01-10 A | 3 | 100% | 2019-01-11 | 2019-01-11 | 1d |  | Steve Masters | 8h | 8h | 1,000 | 1,000 | 1,000 |
| 5 | 1.4 | Secure core resources |  | 1d | 2019-01-11 A | 2019-01-11 A | 4 | 100% | 2019-01-14 | 2019-01-14 | 1d |  | Steve Masters | 8h | 8h | 1,800 | 1,800 | 1,800 |
| 6 | 1.5 | Scope complete | milestone | 0d | 2019-01-11 A | 2019-01-11 A | 5 | 100% | 2019-01-14 | 2019-01-14 | 0d |  |  |  |  |  |  |  |
| 7 | 2 | **Analysis/Software Requirements** |  | 12d | 2019-01-15 A | 2019-01-30 A |  | 100% | 2019-01-15 | 2019-01-30 | 12d |  |  | 116h | 116h | 3,072 | 3,248 | 3,072 |
| 8 | 2.1 | Conduct needs analysis |  | 2d | 2019-01-15 A | 2019-01-16 A | 6 | 100% | 2019-01-15 | 2019-01-16 | 2d |  | Kim Ralls; Rob Young | 32h | 32h | 752 | 752 | 752 |
| 9 | 2.2 | Draft preliminary software specifications |  | 2d | 2019-01-17 A | 2019-01-18 A | 8 | 100% | 2019-01-17 | 2019-01-18 | 2d |  | Kim Ralls [50%]; Rob Young [50%] | 16h | 16h | 376 | 376 | 376 |
| 10 | 2.3 | Develop preliminary budget |  | 3d | 2019-01-22 A | 2019-01-24 A | 9 | 100% | 2019-01-21 | 2019-01-22 | 2d |  | Kim Ralls [50%]; Rob Young | 12h | 12h | 288 | 288 | 288 |
| 11 | 2.4 | Review software specifications/budget with team |  | 1d | 2019-01-22 A | 2019-01-22 A | 10SS | 100% | 2019-01-21 | 2019-01-21 | 1d |  | Steve Masters | 8h | 8h | 600 | 600 | 600 |
| 12 | 2.5 | Incorporate feedback on software specifications |  | 3d | 2019-01-23 A | 2019-01-25 A | 11 | 100% | 2019-01-22 | 2019-01-24 | 3d |  | Kim Ralls | 24h | 24h | 528 | 528 | 528 |
| 13 | 2.6 | Develop delivery timeline |  | 1d | 2019-01-28 A | 2019-01-28 A | 12 | 100% | 2019-01-25 | 2019-01-28 | 2d |  | Kim Ralls | 8h | 8h | 176 | 352 | 176 |
| 14 | 2.7 | Obtain approvals to proceed (concept, timeline, budget) |  | 1d | 2019-01-29 A | 2019-01-29 A | 13 | 100% | 2019-01-29 | 2019-01-29 | 1d |  | Kim Ralls | 8h | 8h | 176 | 176 | 176 |
| 15 | 2.8 | Secure required resources |  | 1d | 2019-01-30 A | 2019-01-30 A | 14 | 100% | 2019-01-30 | 2019-01-30 | 1d |  | Kim Ralls | 8h | 8h | 176 | 176 | 176 |
| 16 | 2.9 | Analysis complete | milestone | 0d | 2019-01-30 A | 2019-01-30 A | 15 | 100% | 2019-01-30 | 2019-01-30 | 0d |  |  |  |  |  |  |  |
| 17 | 3 | **Design** |  | 15d | 2019-01-31 | 2019-02-20 |  |  | 2019-01-31 | 2019-02-20 | 15d | 0d |  | 120h |  | 2,640 | 2,640 |  |
| 18 | 3.1 | Review preliminary software specifications |  | 2d | 2019-01-31 | 2019-02-01 | 16 |  | 2019-01-31 | 2019-02-01 | 2d | 0d | Kim Ralls | 16h |  | 352 | 352 |  |
| 19 | 3.2 | Develop functional specifications |  | 5d | 2019-02-04 | 2019-02-08 | 18 |  | 2019-02-04 | 2019-02-08 | 5d | 0d | Kim Ralls | 40h |  | 880 | 880 |  |
| 20 | 3.3 | Develop prototype based on functional specifications |  | 4d | 2019-02-11 | 2019-02-14 | 19 |  | 2019-02-11 | 2019-02-14 | 4d | 0d | Kim Ralls | 32h |  | 704 | 704 |  |
| 21 | 3.4 | Review functional specifications |  | 2d | 2019-02-15 | 2019-02-18 | 20 |  | 2019-02-15 | 2019-02-18 | 2d | 0d | Kim Ralls | 16h |  | 352 | 352 |  |
| 22 | 3.5 | Incorporate feedback into functional specifications |  | 1d | 2019-02-19 | 2019-02-19 | 21 |  | 2019-02-19 | 2019-02-19 | 1d | 0d | Kim Ralls | 8h |  | 176 | 176 |  |
| 23 | 3.6 | Obtain approval to proceed |  | 1d | 2019-02-20 | 2019-02-20 | 22 |  | 2019-02-20 | 2019-02-20 | 1d | 0d | Kim Ralls | 8h |  | 176 | 176 |  |
| 24 | 3.7 | Design complete | milestone | 0d | 2019-02-20 | 2019-02-20 | 23 |  | 2019-02-20 | 2019-02-20 | 0d | 0d |  |  |  |  |  |  |

| ID | WBS | Task | Type | Duration | Start | Finish | Predecessors | Baseline start | Baseline finish | Baseline duration | Total slack | Free slack | Resources | Work | Cost | Baseline cost |
| --- | --- | --- | --- | --- | --- | --- | --- | --- | --- | --- | --- | --- | --- | --- | --- | --- |
| 25 | 4 | **Development** |  | 33d | 2019-02-21 | 2019-04-08 |  | 2019-02-21 | 2019-04-08 | 33d | 5d |  |  | 264h | 6,600 | 6,600 |
| 26 | 4.1 | Review functional specifications |  | 1d | 2019-02-21 | 2019-02-21 | 24 | 2019-02-21 | 2019-02-21 | 1d | 5d | 0d | Rob Young | 8h | 200 | 200 |
| 27 | 4.2 | Identify modular/tiered design parameters |  | 1d | 2019-02-22 | 2019-02-22 | 26 | 2019-02-22 | 2019-02-22 | 1d | 5d | 0d | Rob Young | 8h | 200 | 200 |
| 28 | 4.3 | Assign development staff |  | 1d | 2019-02-25 | 2019-02-25 | 27 | 2019-02-25 | 2019-02-25 | 1d | 5d | 0d | Rob Young | 8h | 200 | 200 |
| 29 | 4.4 | Develop code |  | 15d | 2019-02-26 | 2019-03-18 | 28 | 2019-02-26 | 2019-03-18 | 15d | 5d | 0d | Rob Young | 120h | 3,000 | 3,000 |
| 30 | 4.5 | Developer testing (primary debugging) |  | 15d | 2019-03-19 | 2019-04-08 | 29FS-7.5% | 2019-03-19 | 2019-04-08 | 15d | 5d | 0d | Rob Young | 120h | 3,000 | 3,000 |
| 31 | 4.6 | Development complete | milestone | 0d | 2019-04-08 | 2019-04-08 | 30 | 2019-04-08 | 2019-04-08 | 0d | 5d | 0d |  |  |  |  |
| 32 | 5 | **Testing** |  | 60d | 2019-02-21 | 2019-05-15 |  | 2019-02-21 | 2019-05-15 | 60d | 20d |  |  | 280h | 9,552 | 9,552 |
| 33 | 5.1 | Develop unit test plans using product specifications |  | 4d | 2019-02-21 | 2019-02-26 | 24 | 2019-02-21 | 2019-02-26 | 4d | 34d | 29d | Steve Masters | 32h | 2,400 | 2,400 |
| 34 | 5.2 | Develop integration test plans using product specifications |  | 4d | 2019-03-04 | 2019-05-01 | 24 | 2019-03-04 | 2019-05-01 | 4d | 30d |  | Steve Masters | 32h | 2,400 | 2,400 |
| 35 | 5.3 | **Unit Testing** |  | 15d | 2019-04-09 | 2019-04-29 |  | 2019-04-09 | 2019-04-29 | 15d | 5d |  |  | 120h | 2,640 | 2,640 |
| 36 | 5.3.1 | Review modular code |  | 5d | 2019-04-09 | 2019-04-15 | 33, 31 | 2019-04-09 | 2019-04-15 | 5d | 5d | 0d | Kim Ralls | 40h | 880 | 880 |
| 37 | 5.3.2 | Test component modules to product specifications |  | 2d | 2019-04-16 | 2019-04-17 | 31, 36 | 2019-04-16 | 2019-04-17 | 2d | 5d | 0d | Kim Ralls | 16h | 352 | 352 |
| 38 | 5.3.3 | Identify anomalies to product specifications |  | 3d | 2019-04-18 | 2019-04-22 | 37 | 2019-04-18 | 2019-04-22 | 3d | 5d | 0d | Kim Ralls | 24h | 528 | 528 |
| 39 | 5.3.4 | Modify code |  | 3d | 2019-04-23 | 2019-04-25 | 38 | 2019-04-23 | 2019-04-25 | 3d | 5d | 0d | Kim Ralls | 24h | 528 | 528 |
| 40 | 5.3.5 | Re-test modified code |  | 2d | 2019-04-26 | 2019-04-29 | 39 | 2019-04-26 | 2019-04-29 | 2d | 5d | 0d | Kim Ralls | 16h | 352 | 352 |
| 41 | 5.3.6 | Unit testing complete | milestone | 0d | 2019-04-29 | 2019-04-29 | 40 | 2019-04-29 | 2019-04-29 | 0d | 5d | 0d |  |  |  |  |
| 42 | 5.4 | **Integration Testing** |  | 12d | 2019-04-30 | 2019-05-15 |  | 2019-04-30 | 2019-05-15 | 12d | 5d |  |  | 96h | 2,112 | 2,112 |
| 43 | 5.4.1 | Test module integration |  | 5d | 2019-04-30 | 2019-05-06 | 41 | 2019-04-30 | 2019-05-06 | 5d | 5d | 0d | Kim Ralls | 40h | 880 | 880 |
| 44 | 5.4.2 | Identify anomalies to specifications |  | 2d | 2019-05-07 | 2019-05-08 | 43 | 2019-05-07 | 2019-05-08 | 2d | 5d | 0d | Kim Ralls | 16h | 352 | 352 |
| 45 | 5.4.3 | Modify code |  | 3d | 2019-05-09 | 2019-05-13 | 44 | 2019-05-09 | 2019-05-13 | 3d | 5d | 0d | Kim Ralls | 24h | 528 | 528 |
| 46 | 5.4.4 | Re-test modified code |  | 2d | 2019-05-14 | 2019-05-15 | 45 | 2019-05-14 | 2019-05-15 | 2d | 5d | 0d | Kim Ralls | 16h | 352 | 352 |
| 47 | 5.4.5 | Integration testing complete | milestone | 0d | 2019-05-15 | 2019-05-15 | 46 | 2019-05-15 | 2019-05-15 | 0d | 5d |  |  |  |  |  |
| 48 | 6 | **Training** |  | 32d | 2019-04-09 | 2019-05-22 |  | 2019-04-09 | 2019-05-22 | 32d | 0d |  |  | 256h | 6,400 | 6,400 |
| 49 | 6.1 | Develop training specifications for end users |  | 3d | 2019-04-09 | 2019-04-11 | 24 | 2019-04-09 | 2019-04-11 | 3d | 5d |  | Rob Young | 24h | 600 | 600 |
| 50 | 6.2 | Develop training specifications for helpdesk support staff |  | 3d | 2019-04-12 | 2019-04-16 | 24 | 2019-04-12 | 2019-04-16 | 3d | 2d |  | Rob Young | 24h | 600 | 600 |
| 51 | 6.3 | Identify training delivery methodology (computer based training, classroom, etc.) |  | 2d | 2019-04-17 | 2019-04-18 | 24 | 2019-04-17 | 2019-04-18 | 2d | 0d |  | Rob Young | 16h | 400 | 400 |
| 52 | 6.4 | Develop training materials |  | 3w | 2019-04-19 | 2019-05-09 | 49, 31, 50, 51 | 2019-04-19 | 2019-05-09 | 3w | 0d |  | Rob Young | 120h | 3,000 | 3,000 |
| 53 | 6.5 | Conduct training usability study |  | 4d | 2019-05-10 | 2019-05-15 | 52 | 2019-05-10 | 2019-05-15 | 4d | 0d |  | Rob Young | 32h | 800 | 800 |
| 54 | 6.6 | Finalize training materials |  | 3d | 2019-05-16 | 2019-05-20 | 53 | 2019-05-16 | 2019-05-20 | 3d | 0d |  | Rob Young | 24h | 600 | 600 |
| 55 | 6.7 | Develop training delivery mechanism |  | 2d | 2019-05-21 | 2019-05-22 | 54 | 2019-05-21 | 2019-05-22 | 2d | 0d |  | Rob Young | 16h | 400 | 400 |
| 56 | 6.8 | Training materials complete | milestone | 0d | 2019-05-22 | 2019-05-22 | 55 | 2019-05-22 | 2019-05-22 | 0d | 0d |  |  |  |  |  |

| ID | WBS | Task | Type | Duration | Start | Finish | Predecessors | Baseline start | Baseline finish | Baseline duration | Total slack | Free slack | Resources | Work | Cost | Baseline cost |
| --- | --- | --- | --- | --- | --- | --- | --- | --- | --- | --- | --- | --- | --- | --- | --- | --- |
| 57 | 7 | **Documentation** |  | 45d | 2019-02-27 | 2019-04-30 |  | 2019-02-27 | 2019-04-30 | 45d | 14d |  |  | 336h | 25,200 | 25,200 |
| 58 | 7.1 | Develop Help specification |  | 1d | 2019-02-27 | 2019-02-27 | 24 | 2019-02-27 | 2019-02-27 | 1d | 19d | 5.5d | Steve Masters | 8h | 600 | 600 |
| 59 | 7.2 | Develop Help system |  | 3w | 2019-03-07 | 2019-03-28 | 58, 29FS-5% | 2019-03-07 | 2019-03-28 | 3w | 13.5d | 0d | Steve Masters | 120h | 9,000 | 9,000 |
| 60 | 7.3 | Review Help documentation |  | 3d | 2019-04-18 | 2019-04-23 | 59 | 2019-04-18 | 2019-04-23 | 3d | 13.5d | 1.5d | Steve Masters | 24h | 1,800 | 1,800 |
| 61 | 7.4 | Incorporate Help documentation feedback |  | 2d | 2019-04-29 | 2019-04-30 | 60 | 2019-04-29 | 2019-04-30 | 2d | 14d | 0d | Steve Masters | 16h | 1,200 | 1,200 |
| 62 | 7.5 | Develop user manuals specifications |  | 2d | 2019-02-28 | 2019-03-01 | 24 | 2019-02-28 | 2019-03-01 | 2d | 19d | 3.5d | Steve Masters | 16h | 1,200 | 1,200 |
| 63 | 7.6 | Develop user manuals |  | 3w | 2019-03-28 | 2019-04-18 | 62, 29FS-5% | 2019-03-28 | 2019-04-18 | 3w | 15.5d | 0d | Steve Masters | 120h | 9,000 | 9,000 |
| 64 | 7.7 | Review all user documentation |  | 2d | 2019-04-23 | 2019-04-25 | 63 | 2019-04-23 | 2019-04-25 | 2d | 15.5d | 0d | Steve Masters | 16h | 1,200 | 1,200 |
| 65 | 7.8 | Incorporate user documentation feedback |  | 2d | 2019-04-25 | 2019-04-29 | 64 | 2019-04-25 | 2019-04-29 | 2d | 15.5d | 1.5d | Steve Masters | 16h | 1,200 | 1,200 |
| 66 | 7.9 | Documentation complete | milestone | 0d | 2019-04-30 | 2019-04-30 | 65, 61 | 2019-04-30 | 2019-04-30 | 0d | 14d | 0d |  |  |  |  |
| 67 | 8 | **Pilot** |  | 23d | 2019-05-01 | 2019-05-31 |  | 2019-05-01 | 2019-05-31 | 23d | 0d |  |  | 72h | 1,800 | 1,800 |
| 68 | 8.1 | Identify test group |  | 1d | 2019-05-01 | 2019-05-01 | 66 | 2019-05-01 | 2019-05-01 | 1d | 14d | 0d | Rob Young | 8h | 200 | 200 |
| 69 | 8.2 | Develop software delivery mechanism |  | 1d | 2019-05-02 | 2019-05-02 | 68 | 2019-05-02 | 2019-05-02 | 1d | 14d |  | Rob Young | 8h | 200 | 200 |
| 70 | 8.3 | Install/deploy software |  | 1d | 2019-05-23 | 2019-05-23 | 47, 69, 66, 56 | 2019-05-23 | 2019-05-23 | 1d | 0d |  | Rob Young | 8h | 200 | 200 |
| 71 | 8.4 | Obtain user feedback |  | 1w | 2019-05-24 | 2019-05-30 | 70 | 2019-05-24 | 2019-05-30 | 1w | 0d |  | Rob Young | 40h | 1,000 | 1,000 |
| 72 | 8.5 | Evaluate testing information |  | 1d | 2019-05-31 | 2019-05-31 | 71 | 2019-05-31 | 2019-05-31 | 1d | 0d |  | Rob Young | 8h | 200 | 200 |
| 73 | 8.6 | Pilot complete | milestone | 0d | 2019-05-31 | 2019-05-31 | 72 | 2019-05-31 | 2019-05-31 | 0d | 0d |  |  |  |  |  |
| 74 | 9 | **Deployment** |  | 5d | 2019-06-03 | 2019-06-07 |  | 2019-06-03 | 2019-06-07 | 5d | 0d |  |  | 40h | 880 | 880 |
| 75 | 9.1 | Determine final deployment strategy |  | 1d | 2019-06-03 | 2019-06-03 | 73 | 2019-06-03 | 2019-06-03 | 1d | 0d |  | Kim Ralls | 8h | 176 | 176 |
| 76 | 9.2 | Develop deployment methodology |  | 1d | 2019-06-04 | 2019-06-04 | 75 | 2019-06-04 | 2019-06-04 | 1d | 0d |  | Kim Ralls | 8h | 176 | 176 |
| 77 | 9.3 | Secure deployment resources |  | 1d | 2019-06-05 | 2019-06-05 | 76 | 2019-06-05 | 2019-06-05 | 1d | 0d |  | Kim Ralls | 8h | 176 | 176 |
| 78 | 9.4 | Train support staff |  | 1d | 2019-06-06 | 2019-06-06 | 77 | 2019-06-06 | 2019-06-06 | 1d | 0d |  | Kim Ralls | 8h | 176 | 176 |
| 79 | 9.5 | Deploy software |  | 1d | 2019-06-07 | 2019-06-07 | 78 | 2019-06-07 | 2019-06-07 | 1d | 0d |  | Kim Ralls | 8h | 176 | 176 |
| 80 | 9.6 | Deployment complete | milestone | 0d | 2019-06-07 | 2019-06-07 | 79 | 2019-06-07 | 2019-06-07 | 0d | 0d |  |  |  |  |  |

| ID | WBS | Task | Type | Duration | Start | Finish | Predecessors | Baseline start | Baseline finish | Baseline duration | Total slack | Resources | Work | Cost | Baseline cost |
| --- | --- | --- | --- | --- | --- | --- | --- | --- | --- | --- | --- | --- | --- | --- | --- |
| 81 | 10 | **Post Implementation Review** |  | 3d | 2019-06-10 | 2019-06-12 |  | 2019-06-10 | 2019-06-12 | 3d | 0d |  | 24h | 600 | 600 |
| 82 | 10.1 | Document lessons learned |  | 1d | 2019-06-10 | 2019-06-10 | 80 | 2019-06-10 | 2019-06-10 | 1d | 0d | Rob Young | 8h | 200 | 200 |
| 83 | 10.2 | Distribute to team members |  | 1d | 2019-06-11 | 2019-06-11 | 82 | 2019-06-11 | 2019-06-11 | 1d | 0d | Rob Young | 8h | 200 | 200 |
| 84 | 10.3 | Create software maintenance team |  | 1d | 2019-06-12 | 2019-06-12 | 83 | 2019-06-12 | 2019-06-12 | 1d | 0d | Rob Young | 8h | 200 | 200 |
| 85 | 10.4 | Post implementation review complete | milestone | 0d | 2019-06-12 | 2019-06-12 | 84 | 2019-06-12 | 2019-06-12 | 0d | 0d |  |  |  |  |
| 86 | 11 | Software development complete | milestone | 0d | 2019-06-12 | 2019-06-12 | 85 | 2019-06-12 | 2019-06-12 | 0d | 0d |  |  |  |  |
