# MP16ADV_Module1

Schedule from MS Project, 2018-08-06 to 2019-01-14, costs in $, A marks actual dates.

## Calendars

- Standard: Mon-Fri 08:00-12:00, 13:00-17:00; Sat-Sun off.

## Resources

| Resource | Group | Rate | Notes |
| --- | --- | --- | --- |
| Steve Masters | PMO | 75 | Cost table A is for project management duties. Cost table B is for developer lead duties. |
| Rob Young |  | 25 |  |
| Kim Ralls |  | 22 |  |
| Paper |  |  |  |
| Flight |  |  |  |
| Project Budget |  |  |  |
| Project Manager |  |  |  |

## Schedule

| ID | WBS | Task | Type | Duration | Start | Finish | Predecessors | Complete | Baseline start | Baseline finish | Baseline duration | Baseline 1 start | Baseline 1 finish | Total slack | Resources | Work | Actual work | Cost | Baseline cost | Actual cost |
| --- | --- | --- | --- | --- | --- | --- | --- | --- | --- | --- | --- | --- | --- | --- | --- | --- | --- | --- | --- | --- |
| 1 | 1 | **Scope** |  | 8d | 2018-08-06 A | 2018-08-15 A |  | 100% | 2018-05-01 | 2018-05-04 | 4d | 2018-08-06 | 2018-08-15 |  |  | 30h | 30h | 4,300 | 2,400 | 3,850 |
| 2 | 1.1 | Determine project scope |  | 1d | 2018-08-06 A | 2018-08-06 A |  | 100% | 2018-05-01 | 2018-05-01 | 1d | 2018-08-06 | 2018-08-06 |  | Steve Masters | 8h | 8h | 600 | 600 | 600 |
| 3 | 1.2 | Secure project sponsorship |  | 3d | 2018-08-07 A | 2018-08-09 A | 2 | 100% | 2018-05-02 | 2018-05-02 | 1d | 2018-08-07 | 2018-08-09 |  | Steve Masters [25%]; Flight [0.6%] | 6h | 6h | 900 | 600 | 450 |
| 4 | 1.3 | Define preliminary resources |  | 1d | 2018-08-10 A | 2018-08-10 A | 3 | 100% | 2018-05-03 | 2018-05-03 | 1d | 2018-08-10 | 2018-08-10 |  | Steve Masters | 8h | 8h | 1,000 |  | 1,000 |
| 5 | 1.4 | Secure core resources |  | 1d | 2018-08-15 A | 2018-08-15 A | 4 | 100% | 2018-05-04 | 2018-05-04 | 1d | 2018-08-15 | 2018-08-15 |  | Steve Masters | 8h | 8h | 1,800 | 1,200 | 1,800 |
| 6 | 1.5 | Scope complete | milestone | 0d | 2018-08-15 A | 2018-08-15 A | 5 | 100% | 2018-05-04 | 2018-05-04 | 0d | 2018-08-15 | 2018-08-15 |  |  |  |  |  |  |  |
| 7 | 2 | **Analysis/Software Requirements** |  | 12d | 2018-08-16 A | 2018-08-31 A |  | 100% | 2018-05-07 | 2018-05-23 | 13d | 2018-08-16 | 2018-08-31 |  |  | 124h | 124h | 3,248 | 3,472 | 3,248 |
| 8 | 2.1 | Conduct needs analysis |  | 2d | 2018-08-16 A | 2018-08-17 A | 6 | 100% | 2018-05-07 | 2018-05-09 | 3d | 2018-08-16 | 2018-08-17 |  | Kim Ralls; Rob Young | 32h | 32h | 752 | 1,128 | 752 |
| 9 | 2.2 | Draft preliminary software specifications |  | 2d | 2018-08-20 A | 2018-08-21 A | 8 | 100% | 2018-05-10 | 2018-05-15 | 4d | 2018-08-20 | 2018-08-21 |  | Kim Ralls [50%]; Rob Young [50%] | 16h | 16h | 376 | 752 | 376 |
| 10 | 2.3 | Develop preliminary budget |  | 2d | 2018-08-22 A | 2018-08-23 A | 9 | 100% | 2018-05-16 | 2018-05-17 | 2d | 2018-08-22 | 2018-08-23 |  | Kim Ralls [50%]; Rob Young | 12h | 12h | 288 | 288 | 288 |
| 11 | 2.4 | Review software specifications/budget with team |  | 1d | 2018-08-22 A | 2018-08-22 A | 10SS | 100% | 2018-05-16 | 2018-05-16 | 1d | 2018-08-22 | 2018-08-22 |  | Steve Masters | 8h | 8h | 600 | 600 | 600 |
| 12 | 2.5 | Incorporate feedback on software specifications |  | 3d | 2018-08-23 A | 2018-08-27 A | 11 | 100% | 2018-05-18 | 2018-05-18 | 1d | 2018-08-23 | 2018-08-27 |  | Kim Ralls | 24h | 24h | 528 | 176 | 528 |
| 13 | 2.6 | Develop delivery timeline |  | 2d | 2018-08-28 A | 2018-08-29 A | 12 | 100% | 2018-05-21 | 2018-05-21 | 1d | 2018-08-28 | 2018-08-29 |  | Kim Ralls | 16h | 16h | 352 | 176 | 352 |
| 14 | 2.7 | Obtain approvals to proceed (concept, timeline, budget) |  | 1d | 2018-08-30 A | 2018-08-30 A | 13 | 100% | 2018-05-22 | 2018-05-22 | 1d | 2018-08-30 | 2018-08-30 |  | Kim Ralls | 8h | 8h | 176 | 176 | 176 |
| 15 | 2.8 | Secure required resources |  | 1d | 2018-08-31 A | 2018-08-31 A | 14 | 100% | 2018-05-23 | 2018-05-23 | 1d | 2018-08-31 | 2018-08-31 |  | Kim Ralls | 8h | 8h | 176 | 176 | 176 |
| 16 | 2.9 | Analysis complete | milestone | 0d | 2018-08-31 A | 2018-08-31 A | 15 | 100% | 2018-05-23 | 2018-05-23 | 0d | 2018-08-31 | 2018-08-31 |  |  |  |  |  |  |  |
| 17 | 3 | **Design** |  | 15d | 2018-09-03 | 2018-09-21 |  |  | 2018-05-24 | 2018-06-13 | 15d | 2018-09-03 | 2018-09-21 | 0d |  | 120h |  | 2,640 | 2,640 |  |
| 18 | 3.1 | Review preliminary software specifications |  | 2d | 2018-09-03 | 2018-09-04 | 16 |  | 2018-05-24 | 2018-05-25 | 2d | 2018-09-03 | 2018-09-04 | 0d | Kim Ralls | 16h |  | 352 | 352 |  |
| 19 | 3.2 | Develop functional specifications |  | 5d | 2018-09-05 | 2018-09-11 | 18 |  | 2018-05-28 | 2018-06-01 | 5d | 2018-09-05 | 2018-09-11 | 0d | Kim Ralls | 40h |  | 880 | 880 |  |
| 20 | 3.3 | Develop prototype based on functional specifications |  | 4d | 2018-09-12 | 2018-09-17 | 19 |  | 2018-06-04 | 2018-06-07 | 4d | 2018-09-12 | 2018-09-17 | 0d | Kim Ralls | 32h |  | 704 | 704 |  |
| 21 | 3.4 | Review functional specifications |  | 2d | 2018-09-18 | 2018-09-19 | 20 |  | 2018-06-08 | 2018-06-11 | 2d | 2018-09-18 | 2018-09-19 | 0d | Kim Ralls | 16h |  | 352 | 352 |  |
| 22 | 3.5 | Incorporate feedback into functional specifications |  | 1d | 2018-09-20 | 2018-09-20 | 21 |  | 2018-06-12 | 2018-06-12 | 1d | 2018-09-20 | 2018-09-20 | 0d | Kim Ralls | 8h |  | 176 | 176 |  |
| 23 | 3.6 | Obtain approval to proceed |  | 1d | 2018-09-21 | 2018-09-21 | 22 |  | 2018-06-13 | 2018-06-13 | 1d | 2018-09-21 | 2018-09-21 | 0d | Kim Ralls | 8h |  | 176 | 176 |  |
| 24 | 3.7 | Design complete | milestone | 0d | 2018-09-21 | 2018-09-21 | 23 |  | 2018-06-13 | 2018-06-13 | 0d | 2018-09-21 | 2018-09-21 | 0d |  |  |  |  |  |  |

| ID | WBS | Task | Type | Duration | Start | Finish | Predecessors | Baseline start | Baseline finish | Baseline duration | Baseline 1 start | Baseline 1 finish | Total slack | Free slack | Resources | Work | Cost | Baseline cost |
| --- | --- | --- | --- | --- | --- | --- | --- | --- | --- | --- | --- | --- | --- | --- | --- | --- | --- | --- |
| 25 | 4 | **Development** |  | 35d | 2018-09-24 | 2018-11-09 |  | 2018-06-14 | 2018-07-30 | 33d | 2018-09-24 | 2018-11-09 | 4d |  |  | 264h | 6,600 | 6,600 |
| 26 | 4.1 | Review functional specifications |  | 1d | 2018-09-24 | 2018-09-24 | 24 | 2018-06-14 | 2018-06-14 | 1d | 2018-09-24 | 2018-09-24 | 4d | 0d | Rob Young | 8h | 200 | 200 |
| 27 | 4.2 | Identify modular/tiered design parameters |  | 1d | 2018-09-25 | 2018-09-25 | 26 | 2018-06-15 | 2018-06-15 | 1d | 2018-09-25 | 2018-09-25 | 4d | 0d | Rob Young | 8h | 200 | 200 |
| 28 | 4.3 | Assign development staff |  | 1d | 2018-09-26 | 2018-09-26 | 27 | 2018-06-18 | 2018-06-18 | 1d | 2018-09-26 | 2018-09-26 | 4d | 0d | Rob Young | 8h | 200 | 200 |
| 29 | 4.4 | Develop code |  | 15d | 2018-09-27 | 2018-10-17 | 28 | 2018-06-19 | 2018-07-09 | 15d | 2018-09-27 | 2018-10-17 | 4d | 0d | Rob Young | 120h | 3,000 | 3,000 |
| 30 | 4.5 | Developer testing (primary debugging) |  | 15d | 2018-10-22 | 2018-11-09 | 29FS-7.5% | 2018-07-10 | 2018-07-30 | 15d | 2018-10-22 | 2018-11-09 | 4d | 0d | Rob Young | 120h | 3,000 | 3,000 |
| 31 | 4.6 | Development complete | milestone | 0d | 2018-11-09 | 2018-11-09 | 30 | 2018-07-30 | 2018-07-30 | 0d | 2018-11-09 | 2018-11-09 | 4d | 0d |  |  |  |  |
| 32 | 5 | **Testing** |  | 62d | 2018-09-24 | 2018-12-18 |  | 2018-06-14 | 2018-09-05 | 60d | 2018-09-24 | 2018-12-18 | 19d |  |  | 280h | 9,552 | 9,552 |
| 33 | 5.1 | Develop unit test plans using product specifications |  | 4d | 2018-09-24 | 2018-09-27 | 24 | 2018-06-14 | 2018-06-19 | 4d | 2018-09-24 | 2018-09-27 | 35d | 31d | Steve Masters | 32h | 2,400 | 2,400 |
| 34 | 5.2 | Develop integration test plans using product specifications |  | 4d | 2018-10-03 | 2018-11-30 | 24 | 2018-06-25 | 2018-08-22 | 4d | 2018-10-03 | 2018-11-30 | 31d |  | Steve Masters | 32h | 2,400 | 2,400 |
| 35 | 5.3 | **Unit Testing** |  | 15d | 2018-11-12 | 2018-11-30 |  | 2018-07-31 | 2018-08-20 | 15d | 2018-11-12 | 2018-11-30 | 4d |  |  | 120h | 2,640 | 2,640 |
| 36 | 5.3.1 | Review modular code |  | 5d | 2018-11-12 | 2018-11-16 | 33, 31 | 2018-07-31 | 2018-08-06 | 5d | 2018-11-12 | 2018-11-16 | 4d | 0d | Kim Ralls | 40h | 880 | 880 |
| 37 | 5.3.2 | Test component modules to product specifications |  | 2d | 2018-11-19 | 2018-11-20 | 31, 36 | 2018-08-07 | 2018-08-08 | 2d | 2018-11-19 | 2018-11-20 | 4d | 0d | Kim Ralls | 16h | 352 | 352 |
| 38 | 5.3.3 | Identify anomalies to product specifications |  | 3d | 2018-11-21 | 2018-11-23 | 37 | 2018-08-09 | 2018-08-13 | 3d | 2018-11-21 | 2018-11-23 | 4d | 0d | Kim Ralls | 24h | 528 | 528 |
| 39 | 5.3.4 | Modify code |  | 3d | 2018-11-26 | 2018-11-28 | 38 | 2018-08-14 | 2018-08-16 | 3d | 2018-11-26 | 2018-11-28 | 4d | 0d | Kim Ralls | 24h | 528 | 528 |
| 40 | 5.3.5 | Re-test modified code |  | 2d | 2018-11-29 | 2018-11-30 | 39 | 2018-08-17 | 2018-08-20 | 2d | 2018-11-29 | 2018-11-30 | 4d | 0d | Kim Ralls | 16h | 352 | 352 |
| 41 | 5.3.6 | Unit testing complete | milestone | 0d | 2018-11-30 | 2018-11-30 | 40 | 2018-08-20 | 2018-08-20 | 0d | 2018-11-30 | 2018-11-30 | 4d | 0d |  |  |  |  |
| 42 | 5.4 | **Integration Testing** |  | 12d | 2018-12-03 | 2018-12-18 |  | 2018-08-21 | 2018-09-05 | 12d | 2018-12-03 | 2018-12-18 | 4d |  |  | 96h | 2,112 | 2,112 |
| 43 | 5.4.1 | Test module integration |  | 5d | 2018-12-03 | 2018-12-07 | 41 | 2018-08-21 | 2018-08-27 | 5d | 2018-12-03 | 2018-12-07 | 4d | 0d | Kim Ralls | 40h | 880 | 880 |
| 44 | 5.4.2 | Identify anomalies to specifications |  | 2d | 2018-12-10 | 2018-12-11 | 43 | 2018-08-28 | 2018-08-29 | 2d | 2018-12-10 | 2018-12-11 | 4d | 0d | Kim Ralls | 16h | 352 | 352 |
| 45 | 5.4.3 | Modify code |  | 3d | 2018-12-12 | 2018-12-14 | 44 | 2018-08-30 | 2018-09-03 | 3d | 2018-12-12 | 2018-12-14 | 4d | 0d | Kim Ralls | 24h | 528 | 528 |
| 46 | 5.4.4 | Re-test modified code |  | 2d | 2018-12-17 | 2018-12-18 | 45 | 2018-09-04 | 2018-09-05 | 2d | 2018-12-17 | 2018-12-18 | 4d | 0d | Kim Ralls | 16h | 352 | 352 |
| 47 | 5.4.5 | Integration testing complete | milestone | 0d | 2018-12-18 | 2018-12-18 | 46 | 2018-09-05 | 2018-09-05 | 0d | 2018-12-18 | 2018-12-18 | 4d |  |  |  |  |  |
| 48 | 6 | **Training** |  | 31d | 2018-11-12 | 2018-12-24 |  | 2018-07-31 | 2018-09-12 | 32d | 2018-11-12 | 2018-12-24 | 0d |  |  | 256h | 6,400 | 6,400 |
| 49 | 6.1 | Develop training specifications for end users |  | 3d | 2018-11-12 | 2018-11-14 | 24 | 2018-07-31 | 2018-08-02 | 3d | 2018-11-12 | 2018-11-14 | 4d |  | Rob Young | 24h | 600 | 600 |
| 50 | 6.2 | Develop training specifications for helpdesk support staff |  | 3d | 2018-11-13 | 2018-11-15 | 24 | 2018-08-03 | 2018-08-07 | 3d | 2018-11-13 | 2018-11-15 | 3d |  | Rob Young | 24h | 600 | 600 |
| 51 | 6.3 | Identify training delivery methodology (computer based training, classroom, etc.) |  | 2d | 2018-11-19 | 2018-11-20 | 24 | 2018-08-08 | 2018-08-09 | 2d | 2018-11-19 | 2018-11-20 | 0d |  | Rob Young | 16h | 400 | 400 |
| 52 | 6.4 | Develop training materials |  | 3w | 2018-11-21 | 2018-12-11 | 49, 31, 50, 51 | 2018-08-10 | 2018-08-30 | 3w | 2018-11-21 | 2018-12-11 | 0d |  | Rob Young | 120h | 3,000 | 3,000 |
| 53 | 6.5 | Conduct training usability study |  | 4d | 2018-12-12 | 2018-12-17 | 52 | 2018-08-31 | 2018-09-05 | 4d | 2018-12-12 | 2018-12-17 | 0d |  | Rob Young | 32h | 800 | 800 |
| 54 | 6.6 | Finalize training materials |  | 3d | 2018-12-18 | 2018-12-20 | 53 | 2018-09-06 | 2018-09-10 | 3d | 2018-12-18 | 2018-12-20 | 0d |  | Rob Young | 24h | 600 | 600 |
| 55 | 6.7 | Develop training delivery mechanism |  | 2d | 2018-12-21 | 2018-12-24 | 54 | 2018-09-11 | 2018-09-12 | 2d | 2018-12-21 | 2018-12-24 | 0d |  | Rob Young | 16h | 400 | 400 |
| 56 | 6.8 | Training materials complete | milestone | 0d | 2018-12-24 | 2018-12-24 | 55 | 2018-09-12 | 2018-09-12 | 0d | 2018-12-24 | 2018-12-24 | 0d |  |  |  |  |  |

| ID | WBS | Task | Type | Duration | Start | Finish | Predecessors | Baseline start | Baseline finish | Baseline duration | Baseline 1 start | Baseline 1 finish | Total slack | Free slack | Resources | Work | Cost | Baseline cost |
| --- | --- | --- | --- | --- | --- | --- | --- | --- | --- | --- | --- | --- | --- | --- | --- | --- | --- | --- |
| 57 | 7 | **Documentation** |  | 44d | 2018-10-01 | 2018-11-29 |  | 2018-06-20 | 2018-08-21 | 45d | 2018-10-01 | 2018-11-29 | 17d |  |  | 336h | 25,200 | 25,200 |
| 58 | 7.1 | Develop Help specification |  | 1d | 2018-10-01 | 2018-10-01 | 24 | 2018-06-20 | 2018-06-20 | 1d | 2018-10-01 | 2018-10-01 | 21d | 4.5d | Steve Masters | 8h | 600 | 600 |
| 59 | 7.2 | Develop Help system |  | 3w | 2018-10-08 | 2018-10-29 | 58, 29FS-5% | 2018-06-28 | 2018-07-19 | 3w | 2018-10-08 | 2018-10-29 | 16.5d | 0d | Steve Masters | 120h | 9,000 | 9,000 |
| 60 | 7.3 | Review Help documentation |  | 3d | 2018-11-19 | 2018-11-22 | 59 | 2018-08-09 | 2018-08-14 | 3d | 2018-11-19 | 2018-11-22 | 16.5d | 0d | Steve Masters | 24h | 1,800 | 1,800 |
| 61 | 7.4 | Incorporate Help documentation feedback |  | 2d | 2018-11-26 | 2018-11-28 | 60 | 2018-08-20 | 2018-08-21 | 2d | 2018-11-26 | 2018-11-28 | 18.5d | 1.5d | Steve Masters | 16h | 1,200 | 1,200 |
| 62 | 7.5 | Develop user manuals specifications |  | 2d | 2018-10-01 | 2018-10-02 | 24 | 2018-06-21 | 2018-06-22 | 2d | 2018-10-01 | 2018-10-02 | 22d | 3.5d | Steve Masters | 16h | 1,200 | 1,200 |
| 63 | 7.6 | Develop user manuals |  | 3w | 2018-10-29 | 2018-11-19 | 62, 29FS-5% | 2018-07-19 | 2018-08-09 | 3w | 2018-10-29 | 2018-11-19 | 18.5d | 1.5d | Steve Masters | 120h | 9,000 | 9,000 |
| 64 | 7.7 | Review all user documentation |  | 2d | 2018-11-26 | 2018-11-27 | 63 | 2018-08-14 | 2018-08-16 | 2d | 2018-11-26 | 2018-11-27 | 17d | 0d | Steve Masters | 16h | 1,200 | 1,200 |
| 65 | 7.8 | Incorporate user documentation feedback |  | 2d | 2018-11-28 | 2018-11-29 | 64 | 2018-08-16 | 2018-08-20 | 2d | 2018-11-28 | 2018-11-29 | 17d | 0d | Steve Masters | 16h | 1,200 | 1,200 |
| 66 | 7.9 | Documentation complete | milestone | 0d | 2018-11-29 | 2018-11-29 | 65, 61 | 2018-08-21 | 2018-08-21 | 0d | 2018-11-29 | 2018-11-29 | 17d |  |  |  |  |  |
| 67 | 8 | **Pilot** |  | 88d | 2018-09-03 | 2019-01-02 |  | 2018-05-24 | 2018-09-21 | 87d | 2018-09-03 | 2019-01-02 | 0d |  |  | 72h | 1,800 | 1,800 |
| 68 | 8.1 | Identify test group |  | 1d | 2018-09-03 | 2018-09-03 | 16 | 2018-05-24 | 2018-05-24 | 1d | 2018-09-03 | 2018-09-03 | 79d | 0d | Rob Young | 8h | 200 | 200 |
| 69 | 8.2 | Develop software delivery mechanism |  | 1d | 2018-09-04 | 2018-09-04 | 68 | 2018-05-25 | 2018-05-25 | 1d | 2018-09-04 | 2018-09-04 | 79d |  | Rob Young | 8h | 200 | 200 |
| 70 | 8.3 | Install/deploy software |  | 1d | 2018-12-25 | 2018-12-25 | 47, 69, 66, 56 | 2018-09-13 | 2018-09-13 | 1d | 2018-12-25 | 2018-12-25 | 0d |  | Rob Young | 8h | 200 | 200 |
| 71 | 8.4 | Obtain user feedback |  | 1w | 2018-12-26 | 2019-01-01 | 70 | 2018-09-14 | 2018-09-20 | 1w | 2018-12-26 | 2019-01-01 | 0d |  | Rob Young | 40h | 1,000 | 1,000 |
| 72 | 8.5 | Evaluate testing information |  | 1d | 2019-01-02 | 2019-01-02 | 71 | 2018-09-21 | 2018-09-21 | 1d | 2019-01-02 | 2019-01-02 | 0d |  | Rob Young | 8h | 200 | 200 |
| 73 | 8.6 | Pilot complete | milestone | 0d | 2019-01-02 | 2019-01-02 | 72 | 2018-09-21 | 2018-09-21 | 0d | 2019-01-02 | 2019-01-02 | 0d |  |  |  |  |  |
| 74 | 9 | **Deployment** |  | 5d | 2019-01-03 | 2019-01-09 |  | 2018-09-24 | 2018-09-28 | 5d | 2019-01-03 | 2019-01-09 | 0d |  |  | 40h | 880 | 880 |
| 75 | 9.1 | Determine final deployment strategy |  | 1d | 2019-01-03 | 2019-01-03 | 73 | 2018-09-24 | 2018-09-24 | 1d | 2019-01-03 | 2019-01-03 | 0d |  | Kim Ralls | 8h | 176 | 176 |
| 76 | 9.2 | Develop deployment methodology |  | 1d | 2019-01-04 | 2019-01-04 | 75 | 2018-09-25 | 2018-09-25 | 1d | 2019-01-04 | 2019-01-04 | 0d |  | Kim Ralls | 8h | 176 | 176 |
| 77 | 9.3 | Secure deployment resources |  | 1d | 2019-01-07 | 2019-01-07 | 76 | 2018-09-26 | 2018-09-26 | 1d | 2019-01-07 | 2019-01-07 | 0d |  | Kim Ralls | 8h | 176 | 176 |
| 78 | 9.4 | Train support staff |  | 1d | 2019-01-08 | 2019-01-08 | 77 | 2018-09-27 | 2018-09-27 | 1d | 2019-01-08 | 2019-01-08 | 0d |  | Kim Ralls | 8h | 176 | 176 |
| 79 | 9.5 | Deploy software |  | 1d | 2019-01-09 | 2019-01-09 | 78 | 2018-09-28 | 2018-09-28 | 1d | 2019-01-09 | 2019-01-09 | 0d |  | Kim Ralls | 8h | 176 | 176 |
| 80 | 9.6 | Deployment complete | milestone | 0d | 2019-01-09 | 2019-01-09 | 79 | 2018-09-28 | 2018-09-28 | 0d | 2019-01-09 | 2019-01-09 | 0d |  |  |  |  |  |

| ID | WBS | Task | Type | Duration | Start | Finish | Predecessors | Baseline start | Baseline finish | Baseline duration | Baseline 1 start | Baseline 1 finish | Total slack | Resources | Work | Cost | Baseline cost |
| --- | --- | --- | --- | --- | --- | --- | --- | --- | --- | --- | --- | --- | --- | --- | --- | --- | --- |
| 81 | 10 | **Post Implementation Review** |  | 3d | 2019-01-10 | 2019-01-14 |  | 2018-10-01 | 2018-10-03 | 3d | 2019-01-10 | 2019-01-14 | 0d |  | 24h | 600 | 600 |
| 82 | 10.1 | Document lessons learned |  | 1d | 2019-01-10 | 2019-01-10 | 80 | 2018-10-01 | 2018-10-01 | 1d | 2019-01-10 | 2019-01-10 | 0d | Rob Young | 8h | 200 | 200 |
| 83 | 10.2 | Distribute to team members |  | 1d | 2019-01-11 | 2019-01-11 | 82 | 2018-10-02 | 2018-10-02 | 1d | 2019-01-11 | 2019-01-11 | 0d | Rob Young | 8h | 200 | 200 |
| 84 | 10.3 | Create software maintenance team |  | 1d | 2019-01-14 | 2019-01-14 | 83 | 2018-10-03 | 2018-10-03 | 1d | 2019-01-14 | 2019-01-14 | 0d | Rob Young | 8h | 200 | 200 |
| 85 | 10.4 | Post implementation review complete | milestone | 0d | 2019-01-14 | 2019-01-14 | 84 | 2018-10-03 | 2018-10-03 | 0d | 2019-01-14 | 2019-01-14 | 0d |  |  |  |  |
| 86 | 11 | Software development template complete | milestone | 0d | 2019-01-14 | 2019-01-14 | 85 | 2018-10-03 | 2018-10-03 | 0d | 2019-01-14 | 2019-01-14 | 0d |  |  |  |  |
