# MP16ADV_Module6

Schedule from MS Project, 2018-05-01 to 2018-10-03, costs in $.

## Calendars

- Standard: Mon-Fri 08:00-12:00, 13:00-17:00; Sat-Sun off.

## Resources

| Resource | Group | Rate | Notes |
| --- | --- | --- | --- |
| Steve Masters | PMO | 75 | Cost table A is for project management duties. Cost table B is for developer lead duties. |
| Rob Young |  | 25 |  |
| Kim Ralls |  | 20 |  |
| Paper |  |  |  |
| Flight |  |  |  |
| Project Budget |  |  |  |
| Project Manager |  |  |  |

## Schedule

| ID | WBS | Task | Type | Duration | Start | Finish | Predecessors | Baseline start | Baseline finish | Baseline duration | Total slack | Resources | Work | Cost | Baseline cost |
| --- | --- | --- | --- | --- | --- | --- | --- | --- | --- | --- | --- | --- | --- | --- | --- |
| 1 | 1 | **Scope** |  | 7d | 2018-05-01 | 2018-05-09 |  | 2018-05-01 | 2018-05-04 | 4d | 0d |  | 50h | 3,000 | 2,400 |
| 2 | 1.1 | Determine project scope |  | 2d | 2018-05-01 | 2018-05-02 |  | 2018-05-01 | 2018-05-01 | 1d | 0d | Steve Masters | 16h | 1,200 | 600 |
| 3 | 1.2 | Secure project sponsorship |  | 1d | 2018-05-03 | 2018-05-03 | 2 | 2018-05-02 | 2018-05-02 | 1d | 0d | Steve Masters [25%]; Flight [0.6%] | 2h | 600 | 600 |
| 4 | 1.3 | Define preliminary resources |  | 3d | 2018-05-04 | 2018-05-08 | 3 | 2018-05-03 | 2018-05-03 | 1d | 0d | Project Manager | 24h |  |  |
| 5 | 1.4 | Secure core resources |  | 1d | 2018-05-09 | 2018-05-09 | 4 | 2018-05-04 | 2018-05-04 | 1d | 0d | Project Manager | 8h | 1,200 | 1,200 |
| 6 | 1.5 | Scope complete | milestone | 0d | 2018-05-09 | 2018-05-09 | 5 | 2018-05-04 | 2018-05-04 | 0d | 0d |  |  |  |  |
| 7 | 2 | **Analysis/Software Requirements** |  | 10d | 2018-05-10 | 2018-05-23 |  | 2018-05-07 | 2018-05-23 | 13d | 0d |  | 100h | 2,720 | 3,472 |
| 8 | 2.1 | Conduct needs analysis |  | 1d | 2018-05-10 | 2018-05-10 | 6 | 2018-05-07 | 2018-05-09 | 3d | 0d | Kim Ralls; Rob Young | 16h | 376 | 1,128 |
| 9 | 2.2 | Draft preliminary software specifications |  | 4d | 2018-05-11 | 2018-05-16 | 8 | 2018-05-10 | 2018-05-15 | 4d | 0d | Kim Ralls [50%]; Rob Young [50%] | 32h | 752 | 752 |
| 10 | 2.3 | Develop preliminary budget |  | 2d | 2018-05-17 | 2018-05-18 | 9 | 2018-05-16 | 2018-05-17 | 2d | 0d | Kim Ralls [50%]; Rob Young | 12h | 288 | 288 |
| 11 | 2.4 | Review software specifications/budget with team |  | 1d | 2018-05-17 | 2018-05-17 | 10SS | 2018-05-16 | 2018-05-16 | 1d | 0d | Steve Masters | 8h | 600 | 600 |
| 12 | 2.5 | Incorporate feedback on software specifications |  | 1d | 2018-05-18 | 2018-05-18 | 11 | 2018-05-18 | 2018-05-18 | 1d | 0d | Kim Ralls | 8h | 176 | 176 |
| 13 | 2.6 | Develop delivery timeline |  | 1d | 2018-05-21 | 2018-05-21 | 12 | 2018-05-21 | 2018-05-21 | 1d | 0d | Kim Ralls | 8h | 176 | 176 |
| 14 | 2.7 | Obtain approvals to proceed (concept, timeline, budget) |  | 1d | 2018-05-22 | 2018-05-22 | 13 | 2018-05-22 | 2018-05-22 | 1d | 0d | Kim Ralls | 8h | 176 | 176 |
| 15 | 2.8 | Secure required resources |  | 1d | 2018-05-23 | 2018-05-23 | 14 | 2018-05-23 | 2018-05-23 | 1d | 0d | Kim Ralls | 8h | 176 | 176 |
| 16 | 2.9 | Analysis complete | milestone | 0d | 2018-05-23 | 2018-05-23 | 15 | 2018-05-23 | 2018-05-23 | 0d | 0d |  |  |  |  |
| 17 | 3 | **Design** |  | 15d | 2018-05-24 | 2018-06-13 |  | 2018-05-24 | 2018-06-13 | 15d | 0d |  | 120h | 2,640 | 2,640 |
| 18 | 3.1 | Review preliminary software specifications |  | 2d | 2018-05-24 | 2018-05-25 | 16 | 2018-05-24 | 2018-05-25 | 2d | 0d | Kim Ralls | 16h | 352 | 352 |
| 19 | 3.2 | Develop functional specifications |  | 5d | 2018-05-28 | 2018-06-01 | 18 | 2018-05-28 | 2018-06-01 | 5d | 0d | Kim Ralls | 40h | 880 | 880 |
| 20 | 3.3 | Develop prototype based on functional specifications |  | 4d | 2018-06-04 | 2018-06-07 | 19 | 2018-06-04 | 2018-06-07 | 4d | 0d | Kim Ralls | 32h | 704 | 704 |
| 21 | 3.4 | Review functional specifications |  | 2d | 2018-06-08 | 2018-06-11 | 20 | 2018-06-08 | 2018-06-11 | 2d | 0d | Kim Ralls | 16h | 352 | 352 |
| 22 | 3.5 | Incorporate feedback into functional specifications |  | 1d | 2018-06-12 | 2018-06-12 | 21 | 2018-06-12 | 2018-06-12 | 1d | 0d | Kim Ralls | 8h | 176 | 176 |
| 23 | 3.6 | Obtain approval to proceed |  | 1d | 2018-06-13 | 2018-06-13 | 22 | 2018-06-13 | 2018-06-13 | 1d | 0d | Kim Ralls | 8h | 176 | 176 |
| 24 | 3.7 | Design complete | milestone | 0d | 2018-06-13 | 2018-06-13 | 23 | 2018-06-13 | 2018-06-13 | 0d | 0d |  |  |  |  |

| ID | WBS | Task | Type | Duration | Start | Finish | Predecessors | Baseline start | Baseline finish | Baseline duration | Total slack | Free slack | Resources | Work | Cost | Baseline cost |
| --- | --- | --- | --- | --- | --- | --- | --- | --- | --- | --- | --- | --- | --- | --- | --- | --- |
| 25 | 4 | **Development** |  | 33d | 2018-06-14 | 2018-07-30 |  | 2018-06-14 | 2018-07-30 | 33d | 5d |  |  | 264h | 6,600 | 6,600 |
| 26 | 4.1 | Review functional specifications |  | 1d | 2018-06-14 | 2018-06-14 | 24 | 2018-06-14 | 2018-06-14 | 1d | 5d | 0d | Rob Young | 8h | 200 | 200 |
| 27 | 4.2 | Identify modular/tiered design parameters |  | 1d | 2018-06-15 | 2018-06-15 | 26 | 2018-06-15 | 2018-06-15 | 1d | 5d | 0d | Rob Young | 8h | 200 | 200 |
| 28 | 4.3 | Assign development staff |  | 1d | 2018-06-18 | 2018-06-18 | 27 | 2018-06-18 | 2018-06-18 | 1d | 5d | 0d | Rob Young | 8h | 200 | 200 |
| 29 | 4.4 | Develop code |  | 15d | 2018-06-19 | 2018-07-09 | 28 | 2018-06-19 | 2018-07-09 | 15d | 5d | 0d | Rob Young | 120h | 3,000 | 3,000 |
| 30 | 4.5 | Developer testing (primary debugging) |  | 15d | 2018-07-10 | 2018-07-30 | 29FS-7.5% | 2018-07-10 | 2018-07-30 | 15d | 5d | 0d | Rob Young | 120h | 3,000 | 3,000 |
| 31 | 4.6 | Development complete | milestone | 0d | 2018-07-30 | 2018-07-30 | 30 | 2018-07-30 | 2018-07-30 | 0d | 5d | 0d |  |  |  |  |
| 32 | 5 | **Testing** |  | 60d | 2018-06-14 | 2018-09-05 |  | 2018-06-14 | 2018-09-05 | 60d | 20d |  |  | 280h | 9,552 | 9,552 |
| 33 | 5.1 | Develop unit test plans using product specifications |  | 4d | 2018-06-14 | 2018-06-19 | 24 | 2018-06-14 | 2018-06-19 | 4d | 34d | 29d | Steve Masters | 32h | 2,400 | 2,400 |
| 34 | 5.2 | Develop integration test plans using product specifications |  | 4d | 2018-06-25 | 2018-08-22 | 24 | 2018-06-25 | 2018-08-22 | 4d | 30d |  | Steve Masters | 32h | 2,400 | 2,400 |
| 35 | 5.3 | **Unit Testing** |  | 15d | 2018-07-31 | 2018-08-20 |  | 2018-07-31 | 2018-08-20 | 15d | 5d |  |  | 120h | 2,640 | 2,640 |
| 36 | 5.3.1 | Review modular code |  | 5d | 2018-07-31 | 2018-08-06 | 33, 31 | 2018-07-31 | 2018-08-06 | 5d | 5d | 0d | Kim Ralls | 40h | 880 | 880 |
| 37 | 5.3.2 | Test component modules to product specifications |  | 2d | 2018-08-07 | 2018-08-08 | 31, 36 | 2018-08-07 | 2018-08-08 | 2d | 5d | 0d | Kim Ralls | 16h | 352 | 352 |
| 38 | 5.3.3 | Identify anomalies to product specifications |  | 3d | 2018-08-09 | 2018-08-13 | 37 | 2018-08-09 | 2018-08-13 | 3d | 5d | 0d | Kim Ralls | 24h | 528 | 528 |
| 39 | 5.3.4 | Modify code |  | 3d | 2018-08-14 | 2018-08-16 | 38 | 2018-08-14 | 2018-08-16 | 3d | 5d | 0d | Kim Ralls | 24h | 528 | 528 |
| 40 | 5.3.5 | Re-test modified code |  | 2d | 2018-08-17 | 2018-08-20 | 39 | 2018-08-17 | 2018-08-20 | 2d | 5d | 0d | Kim Ralls | 16h | 352 | 352 |
| 41 | 5.3.6 | Unit testing complete | milestone | 0d | 2018-08-20 | 2018-08-20 | 40 | 2018-08-20 | 2018-08-20 | 0d | 5d | 0d |  |  |  |  |
| 42 | 5.4 | **Integration Testing** |  | 12d | 2018-08-21 | 2018-09-05 |  | 2018-08-21 | 2018-09-05 | 12d | 5d |  |  | 96h | 2,112 | 2,112 |
| 43 | 5.4.1 | Test module integration |  | 5d | 2018-08-21 | 2018-08-27 | 41 | 2018-08-21 | 2018-08-27 | 5d | 5d | 0d | Kim Ralls | 40h | 880 | 880 |
| 44 | 5.4.2 | Identify anomalies to specifications |  | 2d | 2018-08-28 | 2018-08-29 | 43 | 2018-08-28 | 2018-08-29 | 2d | 5d | 0d | Kim Ralls | 16h | 352 | 352 |
| 45 | 5.4.3 | Modify code |  | 3d | 2018-08-30 | 2018-09-03 | 44 | 2018-08-30 | 2018-09-03 | 3d | 5d | 0d | Kim Ralls | 24h | 528 | 528 |
| 46 | 5.4.4 | Re-test modified code |  | 2d | 2018-09-04 | 2018-09-05 | 45 | 2018-09-04 | 2018-09-05 | 2d | 5d | 0d | Kim Ralls | 16h | 352 | 352 |
| 47 | 5.4.5 | Integration testing complete | milestone | 0d | 2018-09-05 | 2018-09-05 | 46 | 2018-09-05 | 2018-09-05 | 0d | 5d |  |  |  |  |  |
| 48 | 6 | **Training** |  | 32d | 2018-07-31 | 2018-09-12 |  | 2018-07-31 | 2018-09-12 | 32d | 0d |  |  | 256h | 6,400 | 6,400 |
| 49 | 6.1 | Develop training specifications for end users |  | 3d | 2018-07-31 | 2018-08-02 | 24 | 2018-07-31 | 2018-08-02 | 3d | 5d |  | Rob Young | 24h | 600 | 600 |
| 50 | 6.2 | Develop training specifications for helpdesk support staff |  | 3d | 2018-08-03 | 2018-08-07 | 24 | 2018-08-03 | 2018-08-07 | 3d | 2d |  | Rob Young | 24h | 600 | 600 |
| 51 | 6.3 | Identify training delivery methodology (computer based training, classroom, etc.) |  | 2d | 2018-08-08 | 2018-08-09 | 24 | 2018-08-08 | 2018-08-09 | 2d | 0d |  | Rob Young | 16h | 400 | 400 |
| 52 | 6.4 | Develop training materials |  | 3w | 2018-08-10 | 2018-08-30 | 49, 31, 50, 51 | 2018-08-10 | 2018-08-30 | 3w | 0d |  | Rob Young | 120h | 3,000 | 3,000 |
| 53 | 6.5 | Conduct training usability study |  | 4d | 2018-08-31 | 2018-09-05 | 52 | 2018-08-31 | 2018-09-05 | 4d | 0d |  | Rob Young | 32h | 800 | 800 |
| 54 | 6.6 | Finalize training materials |  | 3d | 2018-09-06 | 2018-09-10 | 53 | 2018-09-06 | 2018-09-10 | 3d | 0d |  | Rob Young | 24h | 600 | 600 |
| 55 | 6.7 | Develop training delivery mechanism |  | 2d | 2018-09-11 | 2018-09-12 | 54 | 2018-09-11 | 2018-09-12 | 2d | 0d |  | Rob Young | 16h | 400 | 400 |
| 56 | 6.8 | Training materials complete | milestone | 0d | 2018-09-12 | 2018-09-12 | 55 | 2018-09-12 | 2018-09-12 | 0d | 0d |  |  |  |  |  |

| ID | WBS | Task | Type | Duration | Start | Finish | Predecessors | Baseline start | Baseline finish | Baseline duration | Total slack | Free slack | Resources | Work | Cost | Baseline cost |
| --- | --- | --- | --- | --- | --- | --- | --- | --- | --- | --- | --- | --- | --- | --- | --- | --- |
| 57 | 7 | **Documentation** |  | 45d | 2018-06-20 | 2018-08-21 |  | 2018-06-20 | 2018-08-21 | 45d | 16d |  |  | 336h | 25,200 | 25,200 |
| 58 | 7.1 | Develop Help specification |  | 1d | 2018-06-20 | 2018-06-20 | 24 | 2018-06-20 | 2018-06-20 | 1d | 23d | 5.5d | Steve Masters | 8h | 600 | 600 |
| 59 | 7.2 | Develop Help system |  | 3w | 2018-06-28 | 2018-07-19 | 58, 29FS-5% | 2018-06-28 | 2018-07-19 | 3w | 17.5d | 0d | Steve Masters | 120h | 9,000 | 9,000 |
| 60 | 7.3 | Review Help documentation |  | 3d | 2018-08-09 | 2018-08-14 | 59 | 2018-08-09 | 2018-08-14 | 3d | 17.5d | 1.5d | Steve Masters | 24h | 1,800 | 1,800 |
| 61 | 7.4 | Incorporate Help documentation feedback |  | 2d | 2018-08-20 | 2018-08-21 | 60 | 2018-08-20 | 2018-08-21 | 2d | 16d | 0d | Steve Masters | 16h | 1,200 | 1,200 |
| 62 | 7.5 | Develop user manuals specifications |  | 2d | 2018-06-21 | 2018-06-22 | 24 | 2018-06-21 | 2018-06-22 | 2d | 20d | 3.5d | Steve Masters | 16h | 1,200 | 1,200 |
| 63 | 7.6 | Develop user manuals |  | 3w | 2018-07-19 | 2018-08-09 | 62, 29FS-5% | 2018-07-19 | 2018-08-09 | 3w | 16.5d | 0d | Steve Masters | 120h | 9,000 | 9,000 |
| 64 | 7.7 | Review all user documentation |  | 2d | 2018-08-14 | 2018-08-16 | 63 | 2018-08-14 | 2018-08-16 | 2d | 17.5d | 0d | Steve Masters | 16h | 1,200 | 1,200 |
| 65 | 7.8 | Incorporate user documentation feedback |  | 2d | 2018-08-16 | 2018-08-20 | 64 | 2018-08-16 | 2018-08-20 | 2d | 17.5d | 1.5d | Steve Masters | 16h | 1,200 | 1,200 |
| 66 | 7.9 | Documentation complete | milestone | 0d | 2018-08-21 | 2018-08-21 | 65, 61 | 2018-08-21 | 2018-08-21 | 0d | 16d |  |  |  |  |  |
| 67 | 8 | **Pilot** |  | 87d | 2018-05-24 | 2018-09-21 |  | 2018-05-24 | 2018-09-21 | 87d | 0d |  |  | 72h | 1,800 | 1,800 |
| 68 | 8.1 | Identify test group |  | 1d | 2018-05-24 | 2018-05-24 | 16 | 2018-05-24 | 2018-05-24 | 1d | 78d | 0d | Rob Young | 8h | 200 | 200 |
| 69 | 8.2 | Develop software delivery mechanism |  | 1d | 2018-05-25 | 2018-05-25 | 68 | 2018-05-25 | 2018-05-25 | 1d | 78d |  | Rob Young | 8h | 200 | 200 |
| 70 | 8.3 | Install/deploy software |  | 1d | 2018-09-13 | 2018-09-13 | 47, 69, 66, 56 | 2018-09-13 | 2018-09-13 | 1d | 0d |  | Rob Young | 8h | 200 | 200 |
| 71 | 8.4 | Obtain user feedback |  | 1w | 2018-09-14 | 2018-09-20 | 70 | 2018-09-14 | 2018-09-20 | 1w | 0d |  | Rob Young | 40h | 1,000 | 1,000 |
| 72 | 8.5 | Evaluate testing information |  | 1d | 2018-09-21 | 2018-09-21 | 71 | 2018-09-21 | 2018-09-21 | 1d | 0d |  | Rob Young | 8h | 200 | 200 |
| 73 | 8.6 | Pilot complete | milestone | 0d | 2018-09-21 | 2018-09-21 | 72 | 2018-09-21 | 2018-09-21 | 0d | 0d |  |  |  |  |  |
| 74 | 9 | **Deployment** |  | 5d | 2018-09-24 | 2018-09-28 |  | 2018-09-24 | 2018-09-28 | 5d | 0d |  |  | 40h | 880 | 880 |
| 75 | 9.1 | Determine final deployment strategy |  | 1d | 2018-09-24 | 2018-09-24 | 73 | 2018-09-24 | 2018-09-24 | 1d | 0d |  | Kim Ralls | 8h | 176 | 176 |
| 76 | 9.2 | Develop deployment methodology |  | 1d | 2018-09-25 | 2018-09-25 | 75 | 2018-09-25 | 2018-09-25 | 1d | 0d |  | Kim Ralls | 8h | 176 | 176 |
| 77 | 9.3 | Secure deployment resources |  | 1d | 2018-09-26 | 2018-09-26 | 76 | 2018-09-26 | 2018-09-26 | 1d | 0d |  | Kim Ralls | 8h | 176 | 176 |
| 78 | 9.4 | Train support staff |  | 1d | 2018-09-27 | 2018-09-27 | 77 | 2018-09-27 | 2018-09-27 | 1d | 0d |  | Kim Ralls | 8h | 176 | 176 |
| 79 | 9.5 | Deploy software |  | 1d | 2018-09-28 | 2018-09-28 | 78 | 2018-09-28 | 2018-09-28 | 1d | 0d |  | Kim Ralls | 8h | 176 | 176 |
| 80 | 9.6 | Deployment complete | milestone | 0d | 2018-09-28 | 2018-09-28 | 79 | 2018-09-28 | 2018-09-28 | 0d | 0d |  |  |  |  |  |

| ID | WBS | Task | Type | Duration | Start | Finish | Predecessors | Baseline start | Baseline finish | Baseline duration | Total slack | Resources | Work | Cost | Baseline cost |
| --- | --- | --- | --- | --- | --- | --- | --- | --- | --- | --- | --- | --- | --- | --- | --- |
| 81 | 10 | **Post Implementation Review** |  | 3d | 2018-10-01 | 2018-10-03 |  | 2018-10-01 | 2018-10-03 | 3d | 0d |  | 24h | 600 | 600 |
| 82 | 10.1 | Document lessons learned |  | 1d | 2018-10-01 | 2018-10-01 | 80 | 2018-10-01 | 2018-10-01 | 1d | 0d | Rob Young | 8h | 200 | 200 |
| 83 | 10.2 | Distribute to team members |  | 1d | 2018-10-02 | 2018-10-02 | 82 | 2018-10-02 | 2018-10-02 | 1d | 0d | Rob Young | 8h | 200 | 200 |
| 84 | 10.3 | Create software maintenance team |  | 1d | 2018-10-03 | 2018-10-03 | 83 | 2018-10-03 | 2018-10-03 | 1d | 0d | Rob Young | 8h | 200 | 200 |
| 85 | 10.4 | Post implementation review complete | milestone | 0d | 2018-10-03 | 2018-10-03 | 84 | 2018-10-03 | 2018-10-03 | 0d | 0d |  |  |  |  |
| 86 | 11 | Software development template complete | milestone | 0d | 2018-10-03 | 2018-10-03 | 85 | 2018-10-03 | 2018-10-03 | 0d | 0d |  |  |  |  |
