# Module13- Reporting

Schedule from MS Project, 2019-04-01 to 2019-08-09, costs in $, A marks actual dates.

## Calendars

- Standard: Mon-Fri 08:00-12:00, 13:00-17:00; Sat-Sun off.

## Resources

| Resource | Group | Rate |
| --- | --- | --- |
| Management | Management |  |
| Project manager | Project Management |  |
| Analyst | Analyst |  |
| Developer(s) | Developer |  |
| Tester(s) | IT |  |
| Trainer(s) | IT |  |
| Technical communicator(s) | Management |  |
| Deployment team | IT |  |
| Kim Ralls | Analyst | 75 |
| Suzy Queue | Management | 100 |
| Aaron Painter | Developer | 75 |
| Steve Masters | Project Management | 26.44 |
| Project Budget |  |  |
| Flight |  |  |
| Hotel |  |  |
| Developer | Developer |  |
| LitWare Development LLC | Vendor |  |

## Schedule

| ID | WBS | Task | Type | Duration | Start | Finish | Predecessors | Complete | Baseline start | Baseline finish | Baseline duration | Total slack | Resources | Work | Actual work | Cost | Baseline cost | Actual cost |
| --- | --- | --- | --- | --- | --- | --- | --- | --- | --- | --- | --- | --- | --- | --- | --- | --- | --- | --- |
| 1 | 1 | **Scope** |  | 4d | 2019-04-01 A | 2019-04-04 A |  | 100% | 2019-04-01 | 2019-04-04 | 4d |  |  | 32h | 32h | 2,023.08 | 2,023.08 | 2,023.08 |
| 2 | 1.1 | Determine project scope |  | 1d | 2019-04-01 A | 2019-04-01 A |  | 100% | 2019-04-01 | 2019-04-01 | 1d |  | Suzy Queue | 8h | 8h | 800 | 800 | 800 |
| 3 | 1.2 | Secure project sponsorship |  | 1d | 2019-04-02 A | 2019-04-02 A | 2 | 100% | 2019-04-02 | 2019-04-02 | 1d |  | Suzy Queue | 8h | 8h | 800 | 800 | 800 |
| 4 | 1.3 | Define preliminary resources |  | 1d | 2019-04-03 A | 2019-04-03 A | 3 | 100% | 2019-04-03 | 2019-04-03 | 1d |  | Steve Masters | 8h | 8h | 211.54 | 211.54 | 211.54 |
| 5 | 1.4 | Secure core resources |  | 1d | 2019-04-04 A | 2019-04-04 A | 4 | 100% | 2019-04-04 | 2019-04-04 | 1d |  | Steve Masters | 8h | 8h | 211.54 | 211.54 | 211.54 |
| 6 | 1.5 | Scope complete | milestone | 0d | 2019-04-04 A | 2019-04-04 A | 5 | 100% | 2019-04-04 | 2019-04-04 | 0d |  |  |  |  |  |  |  |
| 7 | 2 | **Analysis/Software Requirements** |  | 12d | 2019-04-05 | 2019-04-22 |  |  | 2019-04-05 | 2019-04-22 | 12d | 0d |  | 136h |  | 9,069.23 | 9,069.23 |  |
| 8 | 2.1 | Conduct needs analysis |  | 5d | 2019-04-05 | 2019-04-11 | 6 |  | 2019-04-05 | 2019-04-11 | 5d | 0d | Suzy Queue | 40h |  | 4,000 | 4,000 |  |
| 9 | 2.2 | Draft preliminary software specifications |  | 3d | 2019-04-10 | 2019-04-12 | 8FS-2d |  | 2019-04-10 | 2019-04-12 | 3d | 0d | Suzy Queue | 24h |  | 2,400 | 2,400 |  |
| 10 | 2.3 | Develop preliminary budget |  | 2d | 2019-04-05 | 2019-04-08 | 8SS |  | 2019-04-05 | 2019-04-08 | 2d | 4d | Steve Masters | 16h |  | 423.08 | 423.08 |  |
| 11 | 2.4 | Review software specifications/budget with team |  | 1d | 2019-04-15 | 2019-04-15 | 10, 9 |  | 2019-04-15 | 2019-04-15 | 1d | 0d | Steve Masters; Kim Ralls | 16h |  | 811.54 | 811.54 |  |
| 12 | 2.5 | Incorporate feedback on software specifications |  | 1d | 2019-04-16 | 2019-04-16 | 11 |  | 2019-04-16 | 2019-04-16 | 1d | 0d | LitWare Development LLC | 8h |  |  |  |  |
| 13 | 2.6 | Develop delivery timeline |  | 1d | 2019-04-17 | 2019-04-17 | 12 |  | 2019-04-17 | 2019-04-17 | 1d | 0d | Steve Masters | 8h |  | 211.54 | 211.54 |  |
| 14 | 2.7 | Obtain approvals to proceed (concept, timeline, budget) |  | 1d | 2019-04-18 | 2019-04-18 | 13 |  | 2019-04-18 | 2019-04-18 | 1d | 0d | Steve Masters; Suzy Queue | 16h |  | 1,011.54 | 1,011.54 |  |
| 15 | 2.8 | Secure required resources |  | 1d | 2019-04-19 | 2019-04-19 | 14 |  | 2019-04-19 | 2019-04-19 | 1d | 0d | Steve Masters | 8h |  | 211.54 | 211.54 |  |
| 16 | 2.9 | Presentation to Leadership |  | 1d | 2019-04-22 | 2019-04-22 | 15 |  | 2019-04-22 | 2019-04-22 | 1d | 0d |  |  |  |  |  |  |
| 17 | 2.10 | Analysis complete | milestone | 0d | 2019-04-22 | 2019-04-22 | 16 |  | 2019-04-22 | 2019-04-22 | 0d | 0d |  |  |  |  |  |  |
| 18 | 3 | **Design** |  | 15d | 2019-04-23 | 2019-05-13 |  |  | 2019-04-23 | 2019-05-13 | 15d | 0d |  | 128h |  | 10,011.54 | 10,011.54 |  |
| 19 | 3.1 | Review preliminary software specifications |  | 2d | 2019-04-23 | 2019-04-24 | 17 |  | 2019-04-23 | 2019-04-24 | 2d | 0d | Kim Ralls | 16h |  | 1,200 | 1,200 |  |
| 20 | 3.2 | Develop functional specifications |  | 5d | 2019-04-25 | 2019-05-01 | 19 |  | 2019-04-25 | 2019-05-01 | 5d | 0d | Kim Ralls | 40h |  | 3,000 | 3,000 |  |
| 21 | 3.3 | Develop prototype based on functional specifications |  | 4d | 2019-05-02 | 2019-05-07 | 20 |  | 2019-05-02 | 2019-05-07 | 4d | 0d | Kim Ralls | 32h |  | 2,400 | 2,400 |  |
| 22 | 3.4 | Review functional specifications |  | 2d | 2019-05-08 | 2019-05-09 | 21 |  | 2019-05-08 | 2019-05-09 | 2d | 0d | Suzy Queue | 16h |  | 1,600 | 1,600 |  |
| 23 | 3.5 | Incorporate feedback into functional specifications |  | 1d | 2019-05-10 | 2019-05-10 | 22 |  | 2019-05-10 | 2019-05-10 | 1d | 0d | Suzy Queue | 8h |  | 800 | 800 |  |
| 24 | 3.6 | Obtain approval to proceed |  | 1d | 2019-05-13 | 2019-05-13 | 23 |  | 2019-05-13 | 2019-05-13 | 1d | 0d | Steve Masters; Suzy Queue | 16h |  | 1,011.54 | 1,011.54 |  |
| 25 | 3.7 | Design complete | milestone | 0d | 2019-05-13 | 2019-05-13 | 24 |  | 2019-05-13 | 2019-05-13 | 0d | 0d |  |  |  |  |  |  |

Notes:
- 8: Interview SME

| ID | WBS | Task | Type | Duration | Start | Finish | Predecessors | Baseline start | Baseline finish | Baseline duration | Total slack | Free slack | Resources | Work | Cost | Baseline cost |
| --- | --- | --- | --- | --- | --- | --- | --- | --- | --- | --- | --- | --- | --- | --- | --- | --- |
| 26 | 4 | **Development** |  | 21.75d | 2019-05-14 | 2019-06-12 |  | 2019-05-14 | 2019-06-12 | 21.75d | 0d |  |  | 264h | 19,800 | 19,800 |
| 27 | 4.1 | Review functional specifications |  | 1d | 2019-05-14 | 2019-05-14 | 25 | 2019-05-14 | 2019-05-14 | 1d | 0d |  | Aaron Painter | 8h | 600 | 600 |
| 28 | 4.2 | Identify modular/tiered design parameters |  | 1d | 2019-05-15 | 2019-05-15 | 27 | 2019-05-15 | 2019-05-15 | 1d | 0d |  | Aaron Painter | 8h | 600 | 600 |
| 29 | 4.3 | Assign development staff |  | 1d | 2019-05-16 | 2019-05-16 | 28 | 2019-05-16 | 2019-05-16 | 1d | 0d |  | Aaron Painter | 8h | 600 | 600 |
| 30 | 4.4 | Develop code |  | 15d | 2019-05-17 | 2019-06-06 | 29 | 2019-05-17 | 2019-06-06 | 15d | 0d |  | Aaron Painter | 120h | 9,000 | 9,000 |
| 31 | 4.5 | Developer testing (primary debugging) |  | 15d | 2019-05-22 | 2019-06-12 | 30FS-7.5% | 2019-05-22 | 2019-06-12 | 15d | 0d |  | Aaron Painter | 120h | 9,000 | 9,000 |
| 32 | 4.6 | Development complete | milestone | 0d | 2019-06-12 | 2019-06-12 | 31 | 2019-06-12 | 2019-06-12 | 0d | 0d |  |  |  |  |  |
| 33 | 5 | **Testing** |  | 48.75d | 2019-05-14 | 2019-07-19 |  | 2019-05-14 | 2019-07-19 | 48.75d | 15d |  |  | 280h |  |  |
| 34 | 5.1 | Develop unit test plans using product specifications |  | 4d | 2019-05-14 | 2019-05-17 | 25 | 2019-05-14 | 2019-05-17 | 4d | 17.75d |  | Tester(s) | 32h |  |  |
| 35 | 5.2 | Develop integration test plans using product specifications |  | 4d | 2019-05-14 | 2019-05-17 | 25 | 2019-05-14 | 2019-05-17 | 4d | 59.75d |  | Tester(s) | 32h |  |  |
| 36 | 5.3 | **Unit Testing** |  | 15d | 2019-06-12 | 2019-07-03 |  | 2019-06-12 | 2019-07-03 | 15d | 0d |  |  | 120h |  |  |
| 37 | 5.3.1 | Review modular code |  | 5d | 2019-06-12 | 2019-06-19 | 34, 32 | 2019-06-12 | 2019-06-19 | 5d | 0d |  | Tester(s) | 40h |  |  |
| 38 | 5.3.2 | Test component modules to product specifications |  | 2d | 2019-06-19 | 2019-06-21 | 32, 37 | 2019-06-19 | 2019-06-21 | 2d | 0d |  | Tester(s) | 16h |  |  |
| 39 | 5.3.3 | Identify anomalies to product specifications |  | 3d | 2019-06-21 | 2019-06-26 | 38 | 2019-06-21 | 2019-06-26 | 3d | 0d |  | Tester(s) | 24h |  |  |
| 40 | 5.3.4 | Modify code |  | 3d | 2019-06-26 | 2019-07-01 | 39 | 2019-06-26 | 2019-07-01 | 3d | 0d |  | Tester(s) | 24h |  |  |
| 41 | 5.3.5 | Re-test modified code |  | 2d | 2019-07-01 | 2019-07-03 | 40 | 2019-07-01 | 2019-07-03 | 2d | 0d |  | Tester(s) | 16h |  |  |
| 42 | 5.3.6 | Unit testing complete | milestone | 0d | 2019-07-03 | 2019-07-03 | 41 | 2019-07-03 | 2019-07-03 | 0d | 0d |  |  |  |  |  |
| 43 | 5.4 | **Integration Testing** |  | 12d | 2019-07-03 | 2019-07-19 |  | 2019-07-03 | 2019-07-19 | 12d | 0d |  |  | 96h |  |  |
| 44 | 5.4.1 | Test module integration |  | 5d | 2019-07-03 | 2019-07-10 | 42 | 2019-07-03 | 2019-07-10 | 5d | 0d |  | Tester(s) | 40h |  |  |
| 45 | 5.4.2 | Identify anomalies to specifications |  | 2d | 2019-07-10 | 2019-07-12 | 44 | 2019-07-10 | 2019-07-12 | 2d | 0d |  | Tester(s) | 16h |  |  |
| 46 | 5.4.3 | Modify code |  | 3d | 2019-07-12 | 2019-07-17 | 45 | 2019-07-12 | 2019-07-17 | 3d | 0d |  | Tester(s) | 24h |  |  |
| 47 | 5.4.4 | Re-test modified code |  | 2d | 2019-07-17 | 2019-07-19 | 46 | 2019-07-17 | 2019-07-19 | 2d | 0d |  | Tester(s) | 16h |  |  |
| 48 | 5.4.5 | Integration testing complete | milestone | 0d | 2019-07-19 | 2019-07-19 | 47 | 2019-07-19 | 2019-07-19 | 0d | 0d |  |  |  |  |  |
| 49 | 6 | **Training** |  | 45.75d | 2019-05-14 | 2019-07-16 |  | 2019-05-14 | 2019-07-16 | 45.75d | 3d |  |  | 256h |  |  |
| 50 | 6.1 | Develop training specifications for end users |  | 3d | 2019-05-14 | 2019-05-16 | 25 | 2019-05-14 | 2019-05-16 | 3d | 21.75d | 18.75d | Trainer(s) | 24h |  |  |
| 51 | 6.2 | Develop training specifications for helpdesk support staff |  | 3d | 2019-05-14 | 2019-05-16 | 25 | 2019-05-14 | 2019-05-16 | 3d | 21.75d | 18.75d | Trainer(s) | 24h |  |  |
| 52 | 6.3 | Identify training delivery methodology (computer based training, classroom, etc.) |  | 2d | 2019-05-14 | 2019-05-15 | 25 | 2019-05-14 | 2019-05-15 | 2d | 22.75d | 19.75d | Trainer(s) | 16h |  |  |
| 53 | 6.4 | Develop training materials |  | 3w | 2019-06-12 | 2019-07-03 | 50, 32, 51, 52 | 2019-06-12 | 2019-07-03 | 3w | 3d | 0d | Trainer(s) | 120h |  |  |
| 54 | 6.5 | Conduct training usability study |  | 4d | 2019-07-03 | 2019-07-09 | 53 | 2019-07-03 | 2019-07-09 | 4d | 3d | 0d | Trainer(s) | 32h |  |  |
| 55 | 6.6 | Finalize training materials |  | 3d | 2019-07-09 | 2019-07-12 | 54 | 2019-07-09 | 2019-07-12 | 3d | 3d | 0d | Trainer(s) | 24h |  |  |
| 56 | 6.7 | Develop training delivery mechanism |  | 2d | 2019-07-12 | 2019-07-16 | 55 | 2019-07-12 | 2019-07-16 | 2d | 3d | 0d | Trainer(s) | 16h |  |  |
| 57 | 6.8 | Training materials complete | milestone | 0d | 2019-07-16 | 2019-07-16 | 56 | 2019-07-16 | 2019-07-16 | 0d | 3d |  |  |  |  |  |

| ID | WBS | Task | Type | Duration | Start | Finish | Predecessors | Baseline start | Baseline finish | Baseline duration | Total slack | Free slack | Resources | Work | Cost | Baseline cost |
| --- | --- | --- | --- | --- | --- | --- | --- | --- | --- | --- | --- | --- | --- | --- | --- | --- |
| 58 | 7 | **Documentation** |  | 30.5d | 2019-05-14 | 2019-06-25 |  | 2019-05-14 | 2019-06-25 | 30.5d | 18.25d |  |  | 336h |  |  |
| 59 | 7.1 | Develop Help specification |  | 1d | 2019-05-14 | 2019-05-14 | 25 | 2019-05-14 | 2019-05-14 | 1d | 27.75d | 9.5d | Technical communicator(s) | 8h |  |  |
| 60 | 7.2 | Develop Help system |  | 3w | 2019-05-28 | 2019-06-18 | 59, 30FS-5% | 2019-05-28 | 2019-06-18 | 3w | 18.25d | 0d | Technical communicator(s) | 120h |  |  |
| 61 | 7.3 | Review Help documentation |  | 3d | 2019-06-18 | 2019-06-21 | 60 | 2019-06-18 | 2019-06-21 | 3d | 18.25d | 0d | Technical communicator(s) | 24h |  |  |
| 62 | 7.4 | Incorporate Help documentation feedback |  | 2d | 2019-06-21 | 2019-06-25 | 61 | 2019-06-21 | 2019-06-25 | 2d | 18.25d | 0d | Technical communicator(s) | 16h |  |  |
| 63 | 7.5 | Develop user manuals specifications |  | 2d | 2019-05-14 | 2019-05-15 | 25 | 2019-05-14 | 2019-05-15 | 2d | 27.75d | 8.5d | Technical communicator(s) | 16h |  |  |
| 64 | 7.6 | Develop user manuals |  | 3w | 2019-05-28 | 2019-06-18 | 63, 30FS-5% | 2019-05-28 | 2019-06-18 | 3w | 19.25d | 0d | Technical communicator(s) | 120h |  |  |
| 65 | 7.7 | Review all user documentation |  | 2d | 2019-06-18 | 2019-06-20 | 64 | 2019-06-18 | 2019-06-20 | 2d | 19.25d | 0d | Technical communicator(s) | 16h |  |  |
| 66 | 7.8 | Incorporate user documentation feedback |  | 2d | 2019-06-20 | 2019-06-24 | 65 | 2019-06-20 | 2019-06-24 | 2d | 19.25d | 1d | Technical communicator(s) | 16h |  |  |
| 67 | 7.9 | Documentation complete | milestone | 0d | 2019-06-25 | 2019-06-25 | 66, 62 | 2019-06-25 | 2019-06-25 | 0d | 18.25d |  |  |  |  |  |
| 68 | 8 | **Pilot** |  | 70.75d | 2019-04-23 | 2019-07-30 |  | 2019-04-23 | 2019-07-30 | 70.75d | 0d |  |  | 64h | 211.54 | 211.54 |
| 69 | 8.1 | Identify test group |  | 1d | 2019-04-23 | 2019-04-23 | 17 | 2019-04-23 | 2019-04-23 | 1d | 61.75d | 0d | Steve Masters | 8h | 211.54 | 211.54 |
| 70 | 8.2 | Develop software delivery mechanism |  | 1d | 2019-04-24 | 2019-04-24 | 69 | 2019-04-24 | 2019-04-24 | 1d | 61.75d |  |  |  |  |  |
| 71 | 8.3 | Install/deploy software |  | 1d | 2019-07-19 | 2019-07-22 | 48, 70, 67, 57 | 2019-07-19 | 2019-07-22 | 1d | 0d |  | Deployment team | 8h |  |  |
| 72 | 8.4 | Obtain user feedback |  | 1w | 2019-07-22 | 2019-07-29 | 71 | 2019-07-22 | 2019-07-29 | 1w | 0d |  | Deployment team | 40h |  |  |
| 73 | 8.5 | Evaluate testing information |  | 1d | 2019-07-29 | 2019-07-30 | 72 | 2019-07-29 | 2019-07-30 | 1d | 0d |  | Deployment team | 8h |  |  |
| 74 | 8.6 | Pilot complete | milestone | 0d | 2019-07-30 | 2019-07-30 | 73 | 2019-07-30 | 2019-07-30 | 0d | 0d |  |  |  |  |  |
| 75 | 9 | **Deployment** |  | 5d | 2019-07-30 | 2019-08-06 |  | 2019-07-30 | 2019-08-06 | 5d | 0d |  |  | 40h |  |  |
| 76 | 9.1 | Determine final deployment strategy |  | 1d | 2019-07-30 | 2019-07-31 | 74 | 2019-07-30 | 2019-07-31 | 1d | 0d |  | Deployment team | 8h |  |  |
| 77 | 9.2 | Develop deployment methodology |  | 1d | 2019-07-31 | 2019-08-01 | 76 | 2019-07-31 | 2019-08-01 | 1d | 0d |  | Deployment team | 8h |  |  |
| 78 | 9.3 | Secure deployment resources |  | 1d | 2019-08-01 | 2019-08-02 | 77 | 2019-08-01 | 2019-08-02 | 1d | 0d |  | Deployment team | 8h |  |  |
| 79 | 9.4 | Train support staff |  | 1d | 2019-08-02 | 2019-08-05 | 78 | 2019-08-02 | 2019-08-05 | 1d | 0d |  | Deployment team | 8h |  |  |
| 80 | 9.5 | Deploy software |  | 1d | 2019-08-05 | 2019-08-06 | 79 | 2019-08-05 | 2019-08-06 | 1d | 0d |  | Deployment team | 8h |  |  |
| 81 | 9.6 | Deployment complete | milestone | 0d | 2019-08-06 | 2019-08-06 | 80 | 2019-08-06 | 2019-08-06 | 0d | 0d |  |  |  |  |  |

| ID | WBS | Task | Type | Duration | Start | Finish | Predecessors | Baseline start | Baseline finish | Baseline duration | Total slack | Resources | Work | Cost | Baseline cost |
| --- | --- | --- | --- | --- | --- | --- | --- | --- | --- | --- | --- | --- | --- | --- | --- |
| 82 | 10 | **Post Implementation Review** |  | 3d | 2019-08-06 | 2019-08-09 |  | 2019-08-06 | 2019-08-09 | 3d | 0d |  | 24h | 634.62 | 634.62 |
| 83 | 10.1 | Document lessons learned |  | 1d | 2019-08-06 | 2019-08-07 | 81 | 2019-08-06 | 2019-08-07 | 1d | 0d | Steve Masters | 8h | 211.54 | 211.54 |
| 84 | 10.2 | Distribute to team members |  | 1d | 2019-08-07 | 2019-08-08 | 83 | 2019-08-07 | 2019-08-08 | 1d | 0d | Steve Masters | 8h | 211.54 | 211.54 |
| 85 | 10.3 | Create software maintenance team |  | 1d | 2019-08-08 | 2019-08-09 | 84 | 2019-08-08 | 2019-08-09 | 1d | 0d | Steve Masters | 8h | 211.54 | 211.54 |
| 86 | 10.4 | Post implementation review complete | milestone | 0d | 2019-08-09 | 2019-08-09 | 85 | 2019-08-09 | 2019-08-09 | 0d | 0d |  |  |  |  |
| 87 | 11 | Software development template complete | milestone | 0d | 2019-08-09 | 2019-08-09 | 86 | 2019-08-09 | 2019-08-09 | 0d | 0d |  |  |  |  |
