# Module4_SubProject_Design

Schedule from MS Project, 2019-03-11 to 2019-04-23, costs in $.

## Calendars

- Standard: Mon-Fri 08:00-12:00, 13:00-17:00; Sat-Sun off.

## Resources

| Resource | Group | Rate | Notes |
| --- | --- | --- | --- |
| Steve Masters | PMO | 75 | Cost table A is for project management duties. Cost table B is for developer lead duties. |
| Rob Young |  | 25 |  |
| Kim Ralls |  | 20 |  |
| Paper |  |  |  |
| Flight |  |  |  |
| Project Budget |  |  |  |
| Project Manager |  |  |  |

## Schedule

| ID | WBS | Task | Type | Duration | Start | Finish | Predecessors | Baseline start | Baseline finish | Baseline duration | Total slack | Resources | Work | Cost | Baseline cost |
| --- | --- | --- | --- | --- | --- | --- | --- | --- | --- | --- | --- | --- | --- | --- | --- |
| 1 | 1 | **Scope** |  | 7d | 2019-03-11 | 2019-03-19 |  | 2018-05-01 | 2018-05-04 | 4d | 0d |  | 50h | 3,000 | 2,400 |
| 2 | 1.1 | Determine project scope |  | 2d | 2019-03-11 | 2019-03-12 |  | 2018-05-01 | 2018-05-01 | 1d | 0d | Steve Masters | 16h | 1,200 | 600 |
| 3 | 1.2 | Secure project sponsorship |  | 1d | 2019-03-13 | 2019-03-13 | 2 | 2018-05-02 | 2018-05-02 | 1d | 0d | Steve Masters [25%]; Flight [0.6%] | 2h | 600 | 600 |
| 4 | 1.3 | Define preliminary resources |  | 3d | 2019-03-14 | 2019-03-18 | 3 | 2018-05-03 | 2018-05-03 | 1d | 0d | Project Manager | 24h |  |  |
| 5 | 1.4 | Secure core resources |  | 1d | 2019-03-19 | 2019-03-19 | 4 | 2018-05-04 | 2018-05-04 | 1d | 0d | Project Manager | 8h | 1,200 | 1,200 |
| 6 | 1.5 | Scope complete | milestone | 0d | 2019-03-19 | 2019-03-19 | 5 | 2018-05-04 | 2018-05-04 | 0d | 0d |  |  |  |  |
| 7 | 2 | **Analysis/Software Requirements** |  | 10d | 2019-03-20 | 2019-04-02 |  | 2018-05-07 | 2018-05-23 | 13d | 0d |  | 100h | 2,720 | 3,472 |
| 8 | 2.1 | Conduct needs analysis |  | 1d | 2019-03-20 | 2019-03-20 | 6 | 2018-05-07 | 2018-05-09 | 3d | 0d | Kim Ralls; Rob Young | 16h | 376 | 1,128 |
| 9 | 2.2 | Draft preliminary software specifications |  | 4d | 2019-03-21 | 2019-03-26 | 8 | 2018-05-10 | 2018-05-15 | 4d | 0d | Kim Ralls [50%]; Rob Young [50%] | 32h | 752 | 752 |
| 10 | 2.3 | Develop preliminary budget |  | 2d | 2019-03-27 | 2019-03-28 | 9 | 2018-05-16 | 2018-05-17 | 2d | 0d | Kim Ralls [50%]; Rob Young | 12h | 288 | 288 |
| 11 | 2.4 | Review software specifications/budget with team |  | 1d | 2019-03-27 | 2019-03-27 | 10SS | 2018-05-16 | 2018-05-16 | 1d | 0d | Steve Masters | 8h | 600 | 600 |
| 12 | 2.5 | Incorporate feedback on software specifications |  | 1d | 2019-03-28 | 2019-03-28 | 11 | 2018-05-18 | 2018-05-18 | 1d | 0d | Kim Ralls | 8h | 176 | 176 |
| 13 | 2.6 | Develop delivery timeline |  | 1d | 2019-03-29 | 2019-03-29 | 12 | 2018-05-21 | 2018-05-21 | 1d | 0d | Kim Ralls | 8h | 176 | 176 |
| 14 | 2.7 | Obtain approvals to proceed (concept, timeline, budget) |  | 1d | 2019-04-01 | 2019-04-01 | 13 | 2018-05-22 | 2018-05-22 | 1d | 0d | Kim Ralls | 8h | 176 | 176 |
| 15 | 2.8 | Secure required resources |  | 1d | 2019-04-02 | 2019-04-02 | 14 | 2018-05-23 | 2018-05-23 | 1d | 0d | Kim Ralls | 8h | 176 | 176 |
| 16 | 2.9 | Analysis complete | milestone | 0d | 2019-04-02 | 2019-04-02 | 15 | 2018-05-23 | 2018-05-23 | 0d | 0d |  |  |  |  |
| 17 | 3 | **Design** |  | 15d | 2019-04-03 | 2019-04-23 |  | 2018-05-24 | 2018-06-13 | 15d | 0d |  | 120h | 2,640 | 2,640 |
| 18 | 3.1 | Review preliminary software specifications |  | 2d | 2019-04-03 | 2019-04-04 | 16 | 2018-05-24 | 2018-05-25 | 2d | 0d | Kim Ralls | 16h | 352 | 352 |
| 19 | 3.2 | Develop functional specifications |  | 5d | 2019-04-05 | 2019-04-11 | 18 | 2018-05-28 | 2018-06-01 | 5d | 0d | Kim Ralls | 40h | 880 | 880 |
| 20 | 3.3 | Develop prototype based on functional specifications |  | 4d | 2019-04-12 | 2019-04-17 | 19 | 2018-06-04 | 2018-06-07 | 4d | 0d | Kim Ralls | 32h | 704 | 704 |
| 21 | 3.4 | Review functional specifications |  | 2d | 2019-04-18 | 2019-04-19 | 20 | 2018-06-08 | 2018-06-11 | 2d | 0d | Kim Ralls | 16h | 352 | 352 |
| 22 | 3.5 | Incorporate feedback into functional specifications |  | 1d | 2019-04-22 | 2019-04-22 | 21 | 2018-06-12 | 2018-06-12 | 1d | 0d | Kim Ralls | 8h | 176 | 176 |
| 23 | 3.6 | Obtain approval to proceed |  | 1d | 2019-04-23 | 2019-04-23 | 22 | 2018-06-13 | 2018-06-13 | 1d | 0d | Kim Ralls | 8h | 176 | 176 |
| 24 | 3.7 | Design complete | milestone | 0d | 2019-04-23 | 2019-04-23 | 23 | 2018-06-13 | 2018-06-13 | 0d | 0d |  |  |  |  |
