# Module4_SubProject_Development

Schedule from MS Project, 2019-06-03 to 2019-09-23, costs in $.

## Calendars

- Standard: Mon-Fri 08:00-12:00, 13:00-17:00; Sat-Sun off.

## Resources

| Resource | Group | Rate | Notes |
| --- | --- | --- | --- |
| Steve Masters | PMO | 75 | Cost table A is for project management duties. Cost table B is for developer lead duties. |
| Rob Young |  | 25 |  |
| Kim Ralls |  | 20 |  |
| Paper |  |  |  |
| Flight |  |  |  |
| Project Budget |  |  |  |
| Project Manager |  |  |  |

## Schedule

| ID | WBS | Task | Type | Duration | Start | Finish | Predecessors | Baseline start | Baseline finish | Baseline duration | Total slack | Free slack | Resources | Work | Cost | Baseline cost |
| --- | --- | --- | --- | --- | --- | --- | --- | --- | --- | --- | --- | --- | --- | --- | --- | --- |
| 1 | 1 | **Development** |  | 35d | 2019-06-03 | 2019-07-19 |  | 2018-06-14 | 2018-07-30 | 33d | 4d |  |  | 264h | 6,600 | 6,600 |
| 2 | 1.1 | Review functional specifications |  | 1d | 2019-06-03 | 2019-06-03 |  | 2018-06-14 | 2018-06-14 | 1d | 4d | 0d | Rob Young | 8h | 200 | 200 |
| 3 | 1.2 | Identify modular/tiered design parameters |  | 1d | 2019-06-04 | 2019-06-04 | 2 | 2018-06-15 | 2018-06-15 | 1d | 4d | 0d | Rob Young | 8h | 200 | 200 |
| 4 | 1.3 | Assign development staff |  | 1d | 2019-06-05 | 2019-06-05 | 3 | 2018-06-18 | 2018-06-18 | 1d | 4d | 0d | Rob Young | 8h | 200 | 200 |
| 5 | 1.4 | Develop code |  | 15d | 2019-06-06 | 2019-06-26 | 4 | 2018-06-19 | 2018-07-09 | 15d | 4d | 0d | Rob Young | 120h | 3,000 | 3,000 |
| 6 | 1.5 | Developer testing (primary debugging) |  | 15d | 2019-07-01 | 2019-07-19 | 5FS-7.5% | 2018-07-10 | 2018-07-30 | 15d | 4d | 0d | Rob Young | 120h | 3,000 | 3,000 |
| 7 | 1.6 | Development complete | milestone | 0d | 2019-07-19 | 2019-07-19 | 6 | 2018-07-30 | 2018-07-30 | 0d | 4d | 0d |  |  |  |  |
| 8 | 2 | **Testing** |  | 62d | 2019-06-03 | 2019-08-27 |  | 2018-06-14 | 2018-09-05 | 60d | 19d |  |  | 280h | 9,552 | 9,552 |
| 9 | 2.1 | Develop unit test plans using product specifications |  | 4d | 2019-06-03 | 2019-06-06 |  | 2018-06-14 | 2018-06-19 | 4d | 35d | 31d | Steve Masters | 32h | 2,400 | 2,400 |
| 10 | 2.2 | Develop integration test plans using product specifications |  | 4d | 2019-06-12 | 2019-08-09 |  | 2018-06-25 | 2018-08-22 | 4d | 31d |  | Steve Masters | 32h | 2,400 | 2,400 |
| 11 | 2.3 | **Unit Testing** |  | 15d | 2019-07-22 | 2019-08-09 |  | 2018-07-31 | 2018-08-20 | 15d | 4d |  |  | 120h | 2,640 | 2,640 |
| 12 | 2.3.1 | Review modular code |  | 5d | 2019-07-22 | 2019-07-26 | 9, 7 | 2018-07-31 | 2018-08-06 | 5d | 4d | 0d | Kim Ralls | 40h | 880 | 880 |
| 13 | 2.3.2 | Test component modules to product specifications |  | 2d | 2019-07-29 | 2019-07-30 | 7, 12 | 2018-08-07 | 2018-08-08 | 2d | 4d | 0d | Kim Ralls | 16h | 352 | 352 |
| 14 | 2.3.3 | Identify anomalies to product specifications |  | 3d | 2019-07-31 | 2019-08-02 | 13 | 2018-08-09 | 2018-08-13 | 3d | 4d | 0d | Kim Ralls | 24h | 528 | 528 |
| 15 | 2.3.4 | Modify code |  | 3d | 2019-08-05 | 2019-08-07 | 14 | 2018-08-14 | 2018-08-16 | 3d | 4d | 0d | Kim Ralls | 24h | 528 | 528 |
| 16 | 2.3.5 | Re-test modified code |  | 2d | 2019-08-08 | 2019-08-09 | 15 | 2018-08-17 | 2018-08-20 | 2d | 4d | 0d | Kim Ralls | 16h | 352 | 352 |
| 17 | 2.3.6 | Unit testing complete | milestone | 0d | 2019-08-09 | 2019-08-09 | 16 | 2018-08-20 | 2018-08-20 | 0d | 4d | 0d |  |  |  |  |
| 18 | 2.4 | **Integration Testing** |  | 12d | 2019-08-12 | 2019-08-27 |  | 2018-08-21 | 2018-09-05 | 12d | 4d |  |  | 96h | 2,112 | 2,112 |
| 19 | 2.4.1 | Test module integration |  | 5d | 2019-08-12 | 2019-08-16 | 17 | 2018-08-21 | 2018-08-27 | 5d | 4d | 0d | Kim Ralls | 40h | 880 | 880 |
| 20 | 2.4.2 | Identify anomalies to specifications |  | 2d | 2019-08-19 | 2019-08-20 | 19 | 2018-08-28 | 2018-08-29 | 2d | 4d | 0d | Kim Ralls | 16h | 352 | 352 |
| 21 | 2.4.3 | Modify code |  | 3d | 2019-08-21 | 2019-08-23 | 20 | 2018-08-30 | 2018-09-03 | 3d | 4d | 0d | Kim Ralls | 24h | 528 | 528 |
| 22 | 2.4.4 | Re-test modified code |  | 2d | 2019-08-26 | 2019-08-27 | 21 | 2018-09-04 | 2018-09-05 | 2d | 4d | 0d | Kim Ralls | 16h | 352 | 352 |
| 23 | 2.4.5 | Integration testing complete | milestone | 0d | 2019-08-27 | 2019-08-27 | 22 | 2018-09-05 | 2018-09-05 | 0d | 4d |  |  |  |  |  |
| 24 | 3 | **Training** |  | 31d | 2019-07-22 | 2019-09-02 |  | 2018-07-31 | 2018-09-12 | 32d | 0d |  |  | 256h | 6,400 | 6,400 |
| 25 | 3.1 | Develop training specifications for end users |  | 3d | 2019-07-22 | 2019-07-24 |  | 2018-07-31 | 2018-08-02 | 3d | 4d |  | Rob Young | 24h | 600 | 600 |
| 26 | 3.2 | Develop training specifications for helpdesk support staff |  | 3d | 2019-07-23 | 2019-07-25 |  | 2018-08-03 | 2018-08-07 | 3d | 3d |  | Rob Young | 24h | 600 | 600 |
| 27 | 3.3 | Identify training delivery methodology (computer based training, classroom, etc.) |  | 2d | 2019-07-29 | 2019-07-30 |  | 2018-08-08 | 2018-08-09 | 2d | 0d |  | Rob Young | 16h | 400 | 400 |
| 28 | 3.4 | Develop training materials |  | 3w | 2019-07-31 | 2019-08-20 | 25, 7, 26, 27 | 2018-08-10 | 2018-08-30 | 3w | 0d |  | Rob Young | 120h | 3,000 | 3,000 |
| 29 | 3.5 | Conduct training usability study |  | 4d | 2019-08-21 | 2019-08-26 | 28 | 2018-08-31 | 2018-09-05 | 4d | 0d |  | Rob Young | 32h | 800 | 800 |
| 30 | 3.6 | Finalize training materials |  | 3d | 2019-08-27 | 2019-08-29 | 29 | 2018-09-06 | 2018-09-10 | 3d | 0d |  | Rob Young | 24h | 600 | 600 |
| 31 | 3.7 | Develop training delivery mechanism |  | 2d | 2019-08-30 | 2019-09-02 | 30 | 2018-09-11 | 2018-09-12 | 2d | 0d |  | Rob Young | 16h | 400 | 400 |
| 32 | 3.8 | Training materials complete | milestone | 0d | 2019-09-02 | 2019-09-02 | 31 | 2018-09-12 | 2018-09-12 | 0d | 0d |  |  |  |  |  |

| ID | WBS | Task | Type | Duration | Start | Finish | Predecessors | Baseline start | Baseline finish | Baseline duration | Total slack | Free slack | Resources | Work | Cost | Baseline cost |
| --- | --- | --- | --- | --- | --- | --- | --- | --- | --- | --- | --- | --- | --- | --- | --- | --- |
| 33 | 4 | **Documentation** |  | 44d | 2019-06-10 | 2019-08-08 |  | 2018-06-20 | 2018-08-21 | 45d | 17d |  |  | 336h | 25,200 | 25,200 |
| 34 | 4.1 | Develop Help specification |  | 1d | 2019-06-10 | 2019-06-10 |  | 2018-06-20 | 2018-06-20 | 1d | 21d | 4.5d | Steve Masters | 8h | 600 | 600 |
| 35 | 4.2 | Develop Help system |  | 3w | 2019-06-17 | 2019-07-08 | 34, 5FS-5% | 2018-06-28 | 2018-07-19 | 3w | 16.5d | 0d | Steve Masters | 120h | 9,000 | 9,000 |
| 36 | 4.3 | Review Help documentation |  | 3d | 2019-07-29 | 2019-08-01 | 35 | 2018-08-09 | 2018-08-14 | 3d | 16.5d | 0d | Steve Masters | 24h | 1,800 | 1,800 |
| 37 | 4.4 | Incorporate Help documentation feedback |  | 2d | 2019-08-05 | 2019-08-07 | 36 | 2018-08-20 | 2018-08-21 | 2d | 18.5d | 1.5d | Steve Masters | 16h | 1,200 | 1,200 |
| 38 | 4.5 | Develop user manuals specifications |  | 2d | 2019-06-10 | 2019-06-11 |  | 2018-06-21 | 2018-06-22 | 2d | 22d | 3.5d | Steve Masters | 16h | 1,200 | 1,200 |
| 39 | 4.6 | Develop user manuals |  | 3w | 2019-07-08 | 2019-07-29 | 38, 5FS-5% | 2018-07-19 | 2018-08-09 | 3w | 18.5d | 1.5d | Steve Masters | 120h | 9,000 | 9,000 |
| 40 | 4.7 | Review all user documentation |  | 2d | 2019-08-05 | 2019-08-06 | 39 | 2018-08-14 | 2018-08-16 | 2d | 17d | 0d | Steve Masters | 16h | 1,200 | 1,200 |
| 41 | 4.8 | Incorporate user documentation feedback |  | 2d | 2019-08-07 | 2019-08-08 | 40 | 2018-08-16 | 2018-08-20 | 2d | 17d | 0d | Steve Masters | 16h | 1,200 | 1,200 |
| 42 | 4.9 | Documentation complete | milestone | 0d | 2019-08-08 | 2019-08-08 | 41, 37 | 2018-08-21 | 2018-08-21 | 0d | 17d |  |  |  |  |  |
| 43 | 5 | **Pilot** |  | 73d | 2019-06-03 | 2019-09-11 |  | 2018-05-24 | 2018-09-21 | 87d | 0d |  |  | 72h | 1,800 | 1,800 |
| 44 | 5.1 | Identify test group |  | 1d | 2019-06-03 | 2019-06-03 |  | 2018-05-24 | 2018-05-24 | 1d | 64d | 0d | Rob Young | 8h | 200 | 200 |
| 45 | 5.2 | Develop software delivery mechanism |  | 1d | 2019-06-04 | 2019-06-04 | 44 | 2018-05-25 | 2018-05-25 | 1d | 64d |  | Rob Young | 8h | 200 | 200 |
| 46 | 5.3 | Install/deploy software |  | 1d | 2019-09-03 | 2019-09-03 | 23, 45, 42, 32 | 2018-09-13 | 2018-09-13 | 1d | 0d |  | Rob Young | 8h | 200 | 200 |
| 47 | 5.4 | Obtain user feedback |  | 1w | 2019-09-04 | 2019-09-10 | 46 | 2018-09-14 | 2018-09-20 | 1w | 0d |  | Rob Young | 40h | 1,000 | 1,000 |
| 48 | 5.5 | Evaluate testing information |  | 1d | 2019-09-11 | 2019-09-11 | 47 | 2018-09-21 | 2018-09-21 | 1d | 0d |  | Rob Young | 8h | 200 | 200 |
| 49 | 5.6 | Pilot complete | milestone | 0d | 2019-09-11 | 2019-09-11 | 48 | 2018-09-21 | 2018-09-21 | 0d | 0d |  |  |  |  |  |
| 50 | 6 | **Deployment** |  | 5d | 2019-09-12 | 2019-09-18 |  | 2018-09-24 | 2018-09-28 | 5d | 0d |  |  | 40h | 880 | 880 |
| 51 | 6.1 | Determine final deployment strategy |  | 1d | 2019-09-12 | 2019-09-12 | 49 | 2018-09-24 | 2018-09-24 | 1d | 0d |  | Kim Ralls | 8h | 176 | 176 |
| 52 | 6.2 | Develop deployment methodology |  | 1d | 2019-09-13 | 2019-09-13 | 51 | 2018-09-25 | 2018-09-25 | 1d | 0d |  | Kim Ralls | 8h | 176 | 176 |
| 53 | 6.3 | Secure deployment resources |  | 1d | 2019-09-16 | 2019-09-16 | 52 | 2018-09-26 | 2018-09-26 | 1d | 0d |  | Kim Ralls | 8h | 176 | 176 |
| 54 | 6.4 | Train support staff |  | 1d | 2019-09-17 | 2019-09-17 | 53 | 2018-09-27 | 2018-09-27 | 1d | 0d |  | Kim Ralls | 8h | 176 | 176 |
| 55 | 6.5 | Deploy software |  | 1d | 2019-09-18 | 2019-09-18 | 54 | 2018-09-28 | 2018-09-28 | 1d | 0d |  | Kim Ralls | 8h | 176 | 176 |
| 56 | 6.6 | Deployment complete | milestone | 0d | 2019-09-18 | 2019-09-18 | 55 | 2018-09-28 | 2018-09-28 | 0d | 0d |  |  |  |  |  |

| ID | WBS | Task | Type | Duration | Start | Finish | Predecessors | Baseline start | Baseline finish | Baseline duration | Total slack | Resources | Work | Cost | Baseline cost |
| --- | --- | --- | --- | --- | --- | --- | --- | --- | --- | --- | --- | --- | --- | --- | --- |
| 57 | 7 | **Post Implementation Review** |  | 3d | 2019-09-19 | 2019-09-23 |  | 2018-10-01 | 2018-10-03 | 3d | 0d |  | 24h | 600 | 600 |
| 58 | 7.1 | Document lessons learned |  | 1d | 2019-09-19 | 2019-09-19 | 56 | 2018-10-01 | 2018-10-01 | 1d | 0d | Rob Young | 8h | 200 | 200 |
| 59 | 7.2 | Distribute to team members |  | 1d | 2019-09-20 | 2019-09-20 | 58 | 2018-10-02 | 2018-10-02 | 1d | 0d | Rob Young | 8h | 200 | 200 |
| 60 | 7.3 | Create software maintenance team |  | 1d | 2019-09-23 | 2019-09-23 | 59 | 2018-10-03 | 2018-10-03 | 1d | 0d | Rob Young | 8h | 200 | 200 |
| 61 | 7.4 | Post implementation review complete | milestone | 0d | 2019-09-23 | 2019-09-23 | 60 | 2018-10-03 | 2018-10-03 | 0d | 0d |  |  |  |  |
| 62 | 8 | Software development template complete | milestone | 0d | 2019-09-23 | 2019-09-23 | 61 | 2018-10-03 | 2018-10-03 | 0d | 0d |  |  |  |  |
