# MP16ADV_Module1

Schedule from MS Project, 2018-08-06 to 2019-01-14, costs in $.

## Calendars

- Standard: Mon-Fri 08:00-12:00, 13:00-17:00; Sat-Sun off.

## Resources

| Resource | Group | Notes |
| --- | --- | --- |
| Steve Masters | PMO | Cost table A is for project management duties. Cost table B is for developer lead duties. |
| Rob Young |  |  |
| Kim Ralls |  |  |
| Paper |  |  |
| Flight |  |  |
| Project Budget |  |  |
| Project Manager |  |  |

## Schedule

| ID | WBS | Task | Type | Duration | Start | Finish | Predecessors | Total slack | Resources | Work | Cost |
| --- | --- | --- | --- | --- | --- | --- | --- | --- | --- | --- | --- |
| 1 | 1 | **Scope** |  | 8d | 2018-08-06 | 2018-08-15 |  | 0d |  | 30h | 450 |
| 2 | 1.1 | Determine project scope |  | 1d | 2018-08-06 | 2018-08-06 |  | 0d | Steve Masters | 8h |  |
| 3 | 1.2 | Secure project sponsorship |  | 3d | 2018-08-07 | 2018-08-09 | 2 | 0d | Steve Masters [25%]; Flight [0.6%] | 6h | 450 |
| 4 | 1.3 | Define preliminary resources |  | 1d | 2018-08-10 | 2018-08-10 | 3 | 0d | Steve Masters | 8h |  |
| 5 | 1.4 | Secure core resources |  | 1d | 2018-08-15 | 2018-08-15 | 4 | 0d | Steve Masters | 8h |  |
| 6 | 1.5 | Scope complete | milestone | 0d | 2018-08-15 | 2018-08-15 | 5 | 0d |  |  |  |
| 7 | 2 | **Analysis/Software Requirements** |  | 12d | 2018-08-16 | 2018-08-31 |  | 0d |  | 124h |  |
| 8 | 2.1 | Conduct needs analysis |  | 2d | 2018-08-16 | 2018-08-17 | 6 | 0d | Kim Ralls; Rob Young | 32h |  |
| 9 | 2.2 | Draft preliminary software specifications |  | 2d | 2018-08-20 | 2018-08-21 | 8 | 0d | Kim Ralls [50%]; Rob Young [50%] | 16h |  |
| 10 | 2.3 | Develop preliminary budget |  | 2d | 2018-08-22 | 2018-08-23 | 9 | 0d | Kim Ralls [50%]; Rob Young | 12h |  |
| 11 | 2.4 | Review software specifications/budget with team |  | 1d | 2018-08-22 | 2018-08-22 | 10SS | 0d | Steve Masters | 8h |  |
| 12 | 2.5 | Incorporate feedback on software specifications |  | 3d | 2018-08-23 | 2018-08-27 | 11 | 0d | Kim Ralls | 24h |  |
| 13 | 2.6 | Develop delivery timeline |  | 2d | 2018-08-28 | 2018-08-29 | 12 | 0d | Kim Ralls | 16h |  |
| 14 | 2.7 | Obtain approvals to proceed (concept, timeline, budget) |  | 1d | 2018-08-30 | 2018-08-30 | 13 | 0d | Kim Ralls | 8h |  |
| 15 | 2.8 | Secure required resources |  | 1d | 2018-08-31 | 2018-08-31 | 14 | 0d | Kim Ralls | 8h |  |
| 16 | 2.9 | Analysis complete | milestone | 0d | 2018-08-31 | 2018-08-31 | 15 | 0d |  |  |  |
| 17 | 3 | **Design** |  | 15d | 2018-09-03 | 2018-09-21 |  | 0d |  | 120h |  |
| 18 | 3.1 | Review preliminary software specifications |  | 2d | 2018-09-03 | 2018-09-04 | 16 | 0d | Kim Ralls | 16h |  |
| 19 | 3.2 | Develop functional specifications |  | 5d | 2018-09-05 | 2018-09-11 | 18 | 0d | Kim Ralls | 40h |  |
| 20 | 3.3 | Develop prototype based on functional specifications |  | 4d | 2018-09-12 | 2018-09-17 | 19 | 0d | Kim Ralls | 32h |  |
| 21 | 3.4 | Review functional specifications |  | 2d | 2018-09-18 | 2018-09-19 | 20 | 0d | Kim Ralls | 16h |  |
| 22 | 3.5 | Incorporate feedback into functional specifications |  | 1d | 2018-09-20 | 2018-09-20 | 21 | 0d | Kim Ralls | 8h |  |
| 23 | 3.6 | Obtain approval to proceed |  | 1d | 2018-09-21 | 2018-09-21 | 22 | 0d | Kim Ralls | 8h |  |
| 24 | 3.7 | Design complete | milestone | 0d | 2018-09-21 | 2018-09-21 | 23 | 0d |  |  |  |

| ID | WBS | Task | Type | Duration | Start | Finish | Predecessors | Total slack | Free slack | Resources | Work |
| --- | --- | --- | --- | --- | --- | --- | --- | --- | --- | --- | --- |
| 25 | 4 | **Development** |  | 35d | 2018-09-24 | 2018-11-09 |  | 4d |  |  | 264h |
| 26 | 4.1 | Review functional specifications |  | 1d | 2018-09-24 | 2018-09-24 | 24 | 4d | 0d | Rob Young | 8h |
| 27 | 4.2 | Identify modular/tiered design parameters |  | 1d | 2018-09-25 | 2018-09-25 | 26 | 4d | 0d | Rob Young | 8h |
| 28 | 4.3 | Assign development staff |  | 1d | 2018-09-26 | 2018-09-26 | 27 | 4d | 0d | Rob Young | 8h |
| 29 | 4.4 | Develop code |  | 15d | 2018-09-27 | 2018-10-17 | 28 | 4d | 0d | Rob Young | 120h |
| 30 | 4.5 | Developer testing (primary debugging) |  | 15d | 2018-10-22 | 2018-11-09 | 29FS-7.5% | 4d | 0d | Rob Young | 120h |
| 31 | 4.6 | Development complete | milestone | 0d | 2018-11-09 | 2018-11-09 | 30 | 4d | 0d |  |  |
| 32 | 5 | **Testing** |  | 62d | 2018-09-24 | 2018-12-18 |  | 19d |  |  | 280h |
| 33 | 5.1 | Develop unit test plans using product specifications |  | 4d | 2018-09-24 | 2018-09-27 | 24 | 35d | 31d | Steve Masters | 32h |
| 34 | 5.2 | Develop integration test plans using product specifications |  | 4d | 2018-10-03 | 2018-11-30 | 24 | 31d |  | Steve Masters | 32h |
| 35 | 5.3 | **Unit Testing** |  | 15d | 2018-11-12 | 2018-11-30 |  | 4d |  |  | 120h |
| 36 | 5.3.1 | Review modular code |  | 5d | 2018-11-12 | 2018-11-16 | 33, 31 | 4d | 0d | Kim Ralls | 40h |
| 37 | 5.3.2 | Test component modules to product specifications |  | 2d | 2018-11-19 | 2018-11-20 | 31, 36 | 4d | 0d | Kim Ralls | 16h |
| 38 | 5.3.3 | Identify anomalies to product specifications |  | 3d | 2018-11-21 | 2018-11-23 | 37 | 4d | 0d | Kim Ralls | 24h |
| 39 | 5.3.4 | Modify code |  | 3d | 2018-11-26 | 2018-11-28 | 38 | 4d | 0d | Kim Ralls | 24h |
| 40 | 5.3.5 | Re-test modified code |  | 2d | 2018-11-29 | 2018-11-30 | 39 | 4d | 0d | Kim Ralls | 16h |
| 41 | 5.3.6 | Unit testing complete | milestone | 0d | 2018-11-30 | 2018-11-30 | 40 | 4d | 0d |  |  |
| 42 | 5.4 | **Integration Testing** |  | 12d | 2018-12-03 | 2018-12-18 |  | 4d |  |  | 96h |
| 43 | 5.4.1 | Test module integration |  | 5d | 2018-12-03 | 2018-12-07 | 41 | 4d | 0d | Kim Ralls | 40h |
| 44 | 5.4.2 | Identify anomalies to specifications |  | 2d | 2018-12-10 | 2018-12-11 | 43 | 4d | 0d | Kim Ralls | 16h |
| 45 | 5.4.3 | Modify code |  | 3d | 2018-12-12 | 2018-12-14 | 44 | 4d | 0d | Kim Ralls | 24h |
| 46 | 5.4.4 | Re-test modified code |  | 2d | 2018-12-17 | 2018-12-18 | 45 | 4d | 0d | Kim Ralls | 16h |
| 47 | 5.4.5 | Integration testing complete | milestone | 0d | 2018-12-18 | 2018-12-18 | 46 | 4d |  |  |  |
| 48 | 6 | **Training** |  | 31d | 2018-11-12 | 2018-12-24 |  | 0d |  |  | 256h |
| 49 | 6.1 | Develop training specifications for end users |  | 3d | 2018-11-12 | 2018-11-14 | 24 | 4d |  | Rob Young | 24h |
| 50 | 6.2 | Develop training specifications for helpdesk support staff |  | 3d | 2018-11-13 | 2018-11-15 | 24 | 3d |  | Rob Young | 24h |
| 51 | 6.3 | Identify training delivery methodology (computer based training, classroom, etc.) |  | 2d | 2018-11-19 | 2018-11-20 | 24 | 0d |  | Rob Young | 16h |
| 52 | 6.4 | Develop training materials |  | 3w | 2018-11-21 | 2018-12-11 | 49, 31, 50, 51 | 0d |  | Rob Young | 120h |
| 53 | 6.5 | Conduct training usability study |  | 4d | 2018-12-12 | 2018-12-17 | 52 | 0d |  | Rob Young | 32h |
| 54 | 6.6 | Finalize training materials |  | 3d | 2018-12-18 | 2018-12-20 | 53 | 0d |  | Rob Young | 24h |
| 55 | 6.7 | Develop training delivery mechanism |  | 2d | 2018-12-21 | 2018-12-24 | 54 | 0d |  | Rob Young | 16h |
| 56 | 6.8 | Training materials complete | milestone | 0d | 2018-12-24 | 2018-12-24 | 55 | 0d |  |  |  |

| ID | WBS | Task | Type | Duration | Start | Finish | Predecessors | Total slack | Free slack | Resources | Work |
| --- | --- | --- | --- | --- | --- | --- | --- | --- | --- | --- | --- |
| 57 | 7 | **Documentation** |  | 44d | 2018-10-01 | 2018-11-29 |  | 17d |  |  | 336h |
| 58 | 7.1 | Develop Help specification |  | 1d | 2018-10-01 | 2018-10-01 | 24 | 21d | 4.5d | Steve Masters | 8h |
| 59 | 7.2 | Develop Help system |  | 3w | 2018-10-08 | 2018-10-29 | 58, 29FS-5% | 16.5d | 0d | Steve Masters | 120h |
| 60 | 7.3 | Review Help documentation |  | 3d | 2018-11-19 | 2018-11-22 | 59 | 16.5d | 0d | Steve Masters | 24h |
| 61 | 7.4 | Incorporate Help documentation feedback |  | 2d | 2018-11-26 | 2018-11-28 | 60 | 18.5d | 1.5d | Steve Masters | 16h |
| 62 | 7.5 | Develop user manuals specifications |  | 2d | 2018-10-01 | 2018-10-02 | 24 | 22d | 3.5d | Steve Masters | 16h |
| 63 | 7.6 | Develop user manuals |  | 3w | 2018-10-29 | 2018-11-19 | 62, 29FS-5% | 18.5d | 1.5d | Steve Masters | 120h |
| 64 | 7.7 | Review all user documentation |  | 2d | 2018-11-26 | 2018-11-27 | 63 | 17d | 0d | Steve Masters | 16h |
| 65 | 7.8 | Incorporate user documentation feedback |  | 2d | 2018-11-28 | 2018-11-29 | 64 | 17d | 0d | Steve Masters | 16h |
| 66 | 7.9 | Documentation complete | milestone | 0d | 2018-11-29 | 2018-11-29 | 65, 61 | 17d |  |  |  |
| 67 | 8 | **Pilot** |  | 88d | 2018-09-03 | 2019-01-02 |  | 0d |  |  | 72h |
| 68 | 8.1 | Identify test group |  | 1d | 2018-09-03 | 2018-09-03 | 16 | 79d | 0d | Rob Young | 8h |
| 69 | 8.2 | Develop software delivery mechanism |  | 1d | 2018-09-04 | 2018-09-04 | 68 | 79d |  | Rob Young | 8h |
| 70 | 8.3 | Install/deploy software |  | 1d | 2018-12-25 | 2018-12-25 | 47, 69, 66, 56 | 0d |  | Rob Young | 8h |
| 71 | 8.4 | Obtain user feedback |  | 1w | 2018-12-26 | 2019-01-01 | 70 | 0d |  | Rob Young | 40h |
| 72 | 8.5 | Evaluate testing information |  | 1d | 2019-01-02 | 2019-01-02 | 71 | 0d |  | Rob Young | 8h |
| 73 | 8.6 | Pilot complete | milestone | 0d | 2019-01-02 | 2019-01-02 | 72 | 0d |  |  |  |
| 74 | 9 | **Deployment** |  | 5d | 2019-01-03 | 2019-01-09 |  | 0d |  |  | 40h |
| 75 | 9.1 | Determine final deployment strategy |  | 1d | 2019-01-03 | 2019-01-03 | 73 | 0d |  | Kim Ralls | 8h |
| 76 | 9.2 | Develop deployment methodology |  | 1d | 2019-01-04 | 2019-01-04 | 75 | 0d |  | Kim Ralls | 8h |
| 77 | 9.3 | Secure deployment resources |  | 1d | 2019-01-07 | 2019-01-07 | 76 | 0d |  | Kim Ralls | 8h |
| 78 | 9.4 | Train support staff |  | 1d | 2019-01-08 | 2019-01-08 | 77 | 0d |  | Kim Ralls | 8h |
| 79 | 9.5 | Deploy software |  | 1d | 2019-01-09 | 2019-01-09 | 78 | 0d |  | Kim Ralls | 8h |
| 80 | 9.6 | Deployment complete | milestone | 0d | 2019-01-09 | 2019-01-09 | 79 | 0d |  |  |  |

| ID | WBS | Task | Type | Duration | Start | Finish | Predecessors | Total slack | Resources | Work |
| --- | --- | --- | --- | --- | --- | --- | --- | --- | --- | --- |
| 81 | 10 | **Post Implementation Review** |  | 3d | 2019-01-10 | 2019-01-14 |  | 0d |  | 24h |
| 82 | 10.1 | Document lessons learned |  | 1d | 2019-01-10 | 2019-01-10 | 80 | 0d | Rob Young | 8h |
| 83 | 10.2 | Distribute to team members |  | 1d | 2019-01-11 | 2019-01-11 | 82 | 0d | Rob Young | 8h |
| 84 | 10.3 | Create software maintenance team |  | 1d | 2019-01-14 | 2019-01-14 | 83 | 0d | Rob Young | 8h |
| 85 | 10.4 | Post implementation review complete | milestone | 0d | 2019-01-14 | 2019-01-14 | 84 | 0d |  |  |
| 86 | 11 | Software development template complete | milestone | 0d | 2019-01-14 | 2019-01-14 | 85 | 0d |  |  |
